# Dorado2002revC

Schedule from MS Project, 2002-03-15 to 2002-11-19, A marks actual dates.
KEE Systems

## Calendars

- Standard: Mon-Fri 08:00-12:00, 13:00-17:00; Sat-Sun off.

## Resources

| Resource |
| --- |
| Hans |
| Drew |
| Sib |
| Farley |
| ME |
| Rob |
| Rich |
| Craig |
| Kent |
| ME TECH |
| EE TECH |
| Shop |
| Kiwi |

## Schedule

| ID | WBS | Task | Duration | Start | Finish | Predecessors | Complete | Remaining | Total slack | Free slack | Constraint | Resources | Work | Actual work |
| --- | --- | --- | --- | --- | --- | --- | --- | --- | --- | --- | --- | --- | --- | --- |
| 1 | 1 | **Dorado Program** | 178d? | 2002-03-15 A | 2002-11-19 |  | 8% | 163.01d? | 0d |  |  |  | 15768.4h | 1749.54h |
| 3 | 1.1 | **Propulsion** | 99d | 2002-05-02 A | 2002-09-17 |  | 1% | 97.57d | 45d |  |  |  | 422h | 2h |
| 4 | 1.1.1 | **Articulated Tail** | 95d | 2002-05-02 | 2002-09-11 |  |  |  | 45d | 0d |  |  | 108h |  |
| 5 | 1.1.1.1 | Design & Build New Electronics Housing | 10d | 2002-05-02 | 2002-05-15 |  |  |  | 130d |  | start no earlier than 2002-05-02 | Farley | 80h |  |
| 6 | 1.1.1.2 | New Linear Actuator Scheme | 7d | 2002-09-03 | 2002-09-11 |  |  |  | 45d |  | start no earlier than 2002-09-03 | Hans [50%] | 28h |  |
| 7 | 1.1.2 | **Drive Electronics** | 24d | 2002-05-06 | 2002-06-06 |  |  |  | 113d | 0d |  |  | 136h |  |
| 8 | 1.1.2.1 | Integrate New Electroincs | 24d | 2002-05-06 | 2002-06-06 |  |  |  | 112d |  | start no earlier than 2002-05-05 | Sib [50%] | 96h |  |
| 9 | 1.1.2.2 | Cabling | 5d | 2002-05-27 | 2002-05-31 |  |  |  | 116d |  | start no earlier than 2002-05-27 | EE TECH | 40h |  |
| 10 | 1.1.3 | Integrate New Tail Into fairing | 5d | 2002-06-07 | 2002-06-13 | 7 |  |  | 112d | 0d |  | Farley | 40h |  |
| 11 | 1.1.4 | Tailcone - Bench Stand Design and Fab | 3d | 2002-05-27 | 2002-05-29 |  |  |  | 124d |  | start no earlier than 2002-05-27 | ME TECH | 24h |  |
| 12 | 1.1.5 | Buoyancy Check / Test | 1d | 2002-06-14 A | 2002-06-14 A | 10 | 100% |  |  |  |  | Drew [25%] | 2h | 2h |
| 13 | 1.1.6 | Test Plan | 5d | 2002-06-14 | 2002-06-20 |  |  |  | 108d |  | start no earlier than 2002-06-14 | Rob | 40h |  |
| 14 | 1.1.7 | **Tailcone Documetation** | 4d | 2002-09-12 | 2002-09-17 | 7, 4 |  |  | 45d |  |  |  | 72h |  |
| 15 | 1.1.7.1 | Mechanical | 3d | 2002-09-12 | 2002-09-16 |  |  |  | 46d |  |  | Farley | 24h |  |
| 16 | 1.1.7.2 | Electrical | 2d | 2002-09-12 | 2002-09-13 |  |  |  | 47d |  | start no earlier than 2002-09-02 | Sib | 16h |  |
| 17 | 1.1.7.3 | Software | 4d | 2002-09-12 | 2002-09-17 |  |  |  | 45d |  | start no earlier than 2002-09-04 | Sib | 32h |  |
| 19 | 1.2 | **Power** | 51d? | 2002-04-15 A | 2002-06-24 |  | 9% | 46.25d? | 163d |  |  | Hans | 1865.2h | 156.57h |
| 20 | 1.2.1 | **Battery Chemistry** | 29d | 2002-04-15 A | 2002-05-23 |  | 15% | 24.7d | 182d |  |  | Hans | 472h | 54.55h |
| 21 | 1.2.1.1 | Check life on current Ag-Zn batteries | 4d | 2002-04-15 A | 2002-04-18 |  | 66% | 1.36d | 119d | 3d | start no earlier than 2002-04-13 | Hans [50%] | 16h | 10.56h |
| 22 | 1.2.1.2 | Trade study to review Batt Chems | 3d | 2002-04-18 A | 2002-04-22 |  | 80% | 0.6d | 117d | 1d | start no earlier than 2002-04-18 | Hans [50%] | 12h | 9.6h |
| 23 | 1.2.1.3 | Thermal Analysis of Battery Pack | 5d | 2002-04-17 | 2002-04-23 |  |  |  | 116d | 0d | start no earlier than 2002-04-17 | Kiwi | 40h |  |
| 24 | 1.2.1.4 | Design Review of Batt Chems | 1d | 2002-04-24 | 2002-04-24 | 21, 22, 23 |  |  | 116d | 0d |  | Hans | 8h |  |
| 25 | 1.2.1.5 | Purchase Batteries | 1d | 2002-04-25 | 2002-04-25 | 24 |  |  | 182d | 0d |  | Hans [50%] | 4h |  |
| 26 | 1.2.1.6 | Assemble Batteries | 5d | 2002-04-26 | 2002-05-02 | 25 |  |  | 182d | 0d |  | EE TECH | 40h |  |
| 27 | 1.2.1.7 | Test Batteries | 15d | 2002-05-03 | 2002-05-23 | 26 |  |  | 182d | 0d |  | EE TECH | 120h |  |

| ID | WBS | Task | Duration | Start | Finish | Predecessors | Complete | Remaining | Total slack | Free slack | Constraint | Resources | Work | Actual work |
| --- | --- | --- | --- | --- | --- | --- | --- | --- | --- | --- | --- | --- | --- | --- |
| 28 | 1.2.2 | **Battery Housing** | 34d | 2002-04-25 A | 2002-06-11 | 24 | 12% | 30d | 172d |  |  | Hans | 544h | 64h |
| 29 | 1.2.2.1 | Design | 10d | 2002-05-01 | 2002-05-14 |  |  |  | 172d | 0d | start no earlier than 2002-05-01 | Craig | 80h |  |
| 30 | 1.2.2.2 | Build | 15d | 2002-05-15 | 2002-06-04 | 29 |  |  | 172d | 0d |  | ME TECH | 120h |  |
| 31 | 1.2.2.3 | Test | 5d | 2002-06-05 | 2002-06-11 | 30 |  |  | 172d |  |  | Craig | 40h |  |
| 32 | 1.2.2.4 | Spec Interconnects | 4d | 2002-04-25 A | 2002-04-30 A |  | 100% |  |  |  | start no earlier than 2002-03-28 | Sib | 32h | 32h |
| 33 | 1.2.3 | **Battery Electronics** | 29d? | 2002-05-01 | 2002-06-10 | 24, 32 |  |  | 171d | 0d |  | Sib | 386h |  |
| 34 | 1.2.3.1 | Concept Design | 5d | 2002-05-01 | 2002-05-07 |  |  |  | 179d | 0d | start no earlier than 2002-04-22 | Sib | 40h |  |
| 35 | 1.2.3.2 | Design Review | 2d | 2002-05-08 | 2002-05-09 | 34 |  |  | 179d | 0d |  | Sib | 16h |  |
| 36 | 1.2.3.3 | Final Design | 11d | 2002-05-10 | 2002-05-24 | 35 |  |  | 179d | 0d | start no earlier than 2002-05-01 | Sib [75%] | 66h |  |
| 37 | 1.2.3.4 | Build | 1d | 2002-05-27 | 2002-05-27 | 36 |  |  | 179d | 0d |  | EE TECH | 8h |  |
| 38 | 1.2.3.5 | Assemble | 1d | 2002-05-28 | 2002-05-28 | 37 |  |  | 179d | 0d |  | EE TECH | 8h |  |
| 39 | 1.2.3.6 | Test | 1d | 2002-05-29 | 2002-05-29 | 38 |  |  | 179d |  |  | EE TECH | 8h |  |
| 40 | 1.2.3.7 | Spec Misc Electronics (Contingency) | 1d? | 2002-06-10 | 2002-06-10 | 27 |  |  | 171d |  | start no earlier than 2002-06-10 | Sib | 8h |  |
| 41 | 1.2.4 | **Battery Charging** | 2d | 2002-06-11 | 2002-06-12 | 24, 33 |  |  | 171d |  |  | Hans | 23.2h |  |
| 42 | 1.2.4.1 | Spec Charging Analysis | 2d | 2002-06-11 | 2002-06-12 |  |  |  | 171d |  |  | Hans [20%] | 3.2h |  |
| 43 | 1.2.4.2 | Order Charging Equip as Required | 1d | 2002-06-11 | 2002-06-11 |  |  |  | 172d |  |  | Hans [50%] | 4h |  |
| 44 | 1.2.5 | AUV Power Systems Meeting | 4d | 2002-06-19 | 2002-06-24 |  |  |  | 163d |  | start no earlier than 2002-06-19 | Hans | 32h |  |
| 46 | 1.3 | **Cabling and Connectors** | 42d | 2002-04-25 A | 2002-06-21 | 24 | 41% | 24.61d | 107d |  |  | Drew | 516h | 217.58h |
| 47 | 1.3.1 | Spec Main Power / Comms Cable&Connectors/Penetrators | 13d | 2002-04-25 A | 2002-05-13 |  | 50% | 6.5d | 124.66d | 0d |  | Hans [50%] | 52h | 26h |
| 48 | 1.3.2 | Spec Charging Connector | 4d | 2002-05-14 | 2002-05-17 | 47 |  |  | 132d |  |  | Hans [25%] | 8h |  |
| 49 | 1.3.3 | Spec Tailcone Comms Cable&Connector/Penetrator | 3d | 2002-04-25 A | 2002-04-29 |  | 80% | 0.6d | 134.66d | 10d | start no earlier than 2002-03-18 | Sib | 24h | 19.2h |
| 50 | 1.3.4 | Spec Science Instrument Connector | 2d | 2002-04-25 A | 2002-04-26 A |  | 100% |  |  |  | start no earlier than 2002-04-24 | Drew [25%] | 4h | 4h |
| 51 | 1.3.5 | Spec DVL and parosci Connectors / Penetrator | 1d | 2002-04-29 A | 2002-04-29 A | 50 | 100% |  |  |  |  | Drew [25%] | 2h | 2h |
| 52 | 1.3.6 | Spec RF/Acoustic/Emer location Connect & Penetrators | 1d | 2002-04-30 A | 2002-04-30 A | 51 | 100% |  |  |  |  | Drew [50%] | 4h | 4h |
| 53 | 1.3.7 | Spec On/Off Connector/Penetrator | 1d | 2002-05-01 A | 2002-05-01 A | 52 | 100% |  |  |  |  | Drew [25%] | 2h | 2h |
| 54 | 1.3.8 | Test ability of 100 MB/s thrugh current ALTEX Cable | 2d | 2002-05-21 A | 2002-05-22 A |  | 100% |  |  |  | start no earlier than 2002-05-21 | Drew | 16h | 16h |
| 55 | 1.3.9 | Order Connectors | 2d | 2002-05-14 A | 2002-05-15 | 47, 49, 53 | 33% | 1.34d | 124d | 0d |  | Drew | 16h | 5.28h |

| ID | WBS | Task | Duration | Start | Finish | Predecessors | Complete | Remaining | Total slack | Free slack | Constraint | Resources | Work | Actual work |
| --- | --- | --- | --- | --- | --- | --- | --- | --- | --- | --- | --- | --- | --- | --- |
| 56 | 1.3.10 | **Tail to MVC** | 1d | 2002-05-09 | 2002-05-09 |  |  |  | 128d |  |  | Drew | 12h |  |
| 57 | 1.3.10.1 | Section Interconnect | 1d | 2002-05-09 | 2002-05-09 |  |  |  | 128d | 4d | start no earlier than 2002-05-09 | Drew [50%] | 4h |  |
| 58 | 1.3.11 | Documetation package on Connectors and Cabling | 10d | 2002-06-10 | 2002-06-21 | 55, 57 |  |  | 107d |  | start no earlier than 2002-06-10 | Drew [50%] | 40h |  |
| 60 | 1.4 | **Main Vehicle Computer** | 135d | 2002-03-15 A | 2002-09-19 |  | 33% | 90.68d | 43d |  |  | Sib | 3454h | 1144.88h |
| 61 | 1.4.1 | **Electronics** | 59d | 2002-03-15 A | 2002-06-05 |  | 45% | 32.16d | 119d |  |  | Sib | 1510h | 691.55h |
| 62 | 1.4.1.1 | Spec PC 104 Stack | 2d | 2002-03-15 A | 2002-03-18 A |  | 100% |  |  |  |  | Sib | 16h | 16h |
| 63 | 1.4.1.2 | Order PC 104 Stack | 2d | 2002-03-19 A | 2002-05-07 | 62 | 40% | 1.2d | 138.8d | 0d |  | Sib | 16h | 6.4h |
| 64 | 1.4.1.3 | Assemble PC 104 Stack | 2d | 2002-05-07 | 2002-05-09 | 63 |  |  | 138.8d |  |  | EE TECH | 16h |  |
| 65 | 1.4.1.4 | Develop latency test/budget for MVC | 4d | 2002-05-13 | 2002-05-16 |  |  |  | 133d |  | start no earlier than 2002-05-11 | Sib [50%] | 16h |  |
| 66 | 1.4.1.5 | **Power Board** | 23d | 2002-04-28 A | 2002-05-29 | 24 | 50% | 11.5d | 114d | 70d |  | Sib | 282h | 133h |
| 67 | 1.4.1.5.1 | Specify | 4d | 2002-04-28 A | 2002-05-02 A |  | 100% |  |  |  | start no earlier than 2002-05-06 | Sib [50%] | 16h | 16h |
| 68 | 1.4.1.5.2 | Design | 15d | 2002-05-03 A | 2002-05-23 | 67 | 50% | 7.5d | 114d | 0d |  | Sib [75%] | 90h | 45h |
| 69 | 1.4.1.5.3 | Order | 1d | 2002-05-24 | 2002-05-24 | 68 |  |  | 114d | 0d |  | Sib | 8h |  |
| 70 | 1.4.1.5.4 | Build | 2d | 2002-05-27 | 2002-05-28 | 69 |  |  | 114d | 0d |  | EE TECH | 16h |  |
| 71 | 1.4.1.5.5 | Test | 1d | 2002-05-29 | 2002-05-29 | 70 |  |  | 114d |  |  | EE TECH | 8h |  |
| 72 | 1.4.1.6 | **RF Modem** | 44d | 2002-03-15 A | 2002-05-15 |  | 71% | 12.57d | 134d |  |  | Drew | 376h | 271.43h |
| 73 | 1.4.1.6.1 | Evaluate Data-link vs Freewave | 5d | 2002-03-15 A | 2002-03-21 A |  | 100% |  |  |  |  | Drew [50%] | 20h | 20h |
| 74 | 1.4.1.6.2 | Purchase | 2d | 2002-05-14 | 2002-05-15 |  |  |  | 134d |  | start no earlier than 2002-05-14 | Drew [25%] | 4h |  |
| 75 | 1.4.1.7 | **Acoustic Modem** | 2d | 2002-05-17 | 2002-05-20 |  |  |  | 121d | 77d |  | Hans | 24h |  |
| 76 | 1.4.1.7.1 | Evaluate | 1d | 2002-05-17 | 2002-05-17 |  |  |  | 121d | 0d | start no earlier than 2002-05-17 | Hans [50%] | 4h |  |
| 77 | 1.4.1.7.2 | Purchase | 1d | 2002-05-20 | 2002-05-20 | 76 |  |  | 121d |  |  | Hans [50%] | 4h |  |
| 78 | 1.4.1.8 | **GPS** | 15d | 2002-05-16 | 2002-06-05 |  |  |  | 109d | 65d |  | Drew | 234h |  |
| 79 | 1.4.1.8.1 | Evaluate GPS Position Fix Problem | 10d | 2002-05-16 | 2002-05-29 |  |  |  | 109d | 0d | start no earlier than 2002-05-16 | Craig | 80h |  |
| 80 | 1.4.1.8.2 | Evaluate GPS Board & Antennae | 4d | 2002-05-30 | 2002-06-04 | 79 |  |  | 109d | 0d |  | Craig | 32h |  |
| 81 | 1.4.1.8.3 | Purchase GPS Board & Antennae | 1d | 2002-06-05 | 2002-06-05 | 80 |  |  | 109d |  |  | Drew [25%] | 2h |  |
| 82 | 1.4.1.9 | Eval and Purchase 10/100 Hub | 4d | 2002-03-20 A | 2002-03-25 A |  | 100% |  |  |  | start no earlier than 2002-03-20 | Sib [25%] | 8h | 8h |
| 83 | 1.4.1.10 | Eval & Purchase AHRS | 1d | 2002-03-15 A | 2002-03-15 A |  | 100% |  |  |  |  | Drew [25%] | 2h | 2h |
| 84 | 1.4.1.11 | Eval and Purchase LBL Board Set | 4d | 2002-03-15 A | 2002-03-20 A |  | 100% |  |  |  |  | Hans [25%] | 8h | 8h |
| 85 | 1.4.1.12 | Spec and Purcahse DVL | 5d | 2002-05-14 A | 2002-05-20 |  | 80% | 1d | 131d |  |  | Rob | 40h | 32h |

| ID | WBS | Task | Duration | Start | Finish | Predecessors | Complete | Remaining | Total slack | Free slack | Constraint | Resources | Work | Actual work |
| --- | --- | --- | --- | --- | --- | --- | --- | --- | --- | --- | --- | --- | --- | --- |
| 86 | 1.4.2 | **MVC Housing** | 58d | 2002-03-15 A | 2002-06-04 |  | 17% | 48.06d | 110d |  |  | Drew | 664h | 98.74h |
| 87 | 1.4.2.1 | Spec Interconnects | 6d | 2002-03-15 A | 2002-03-22 |  | 80% | 1.2d | 140d | 0d |  | Drew [50%] | 24h | 19.2h |
| 88 | 1.4.2.2 | Design | 5d | 2002-05-06 | 2002-05-10 | 87 |  |  | 110d | 0d | start no earlier than 2002-05-04 | Farley | 40h |  |
| 89 | 1.4.2.3 | Build/Purchase | 10d | 2002-05-13 | 2002-05-24 | 88 |  |  | 110d | 0d |  | Shop | 80h |  |
| 90 | 1.4.2.4 | Pressure Test | 2d | 2002-05-27 | 2002-05-28 | 89 |  |  | 110d | 0d |  | ME TECH | 16h |  |
| 91 | 1.4.2.5 | Electronics Packagin Layout | 5d | 2002-05-29 | 2002-06-04 | 90 |  |  | 110d | 63d |  | Drew | 40h |  |
| 92 | 1.4.3 | **Documentation Package** | 11d | 2002-09-05 | 2002-09-19 | 91, 78, 75, 66 |  |  | 43d |  |  | Sib | 200h |  |
| 93 | 1.4.3.1 | Mechanical | 2d | 2002-09-05 | 2002-09-06 |  |  |  | 50d | 0d | start no earlier than 2002-09-05 | Farley | 16h |  |
| 94 | 1.4.3.2 | Electrical | 8d | 2002-09-05 | 2002-09-16 |  |  |  | 44d | 0d | start no earlier than 2002-09-05 | Sib | 64h |  |
| 95 | 1.4.3.3 | Software | 2d | 2002-09-16 | 2002-09-17 |  |  |  | 43d | 0d | start no earlier than 2002-09-16 | Hans | 16h |  |
| 96 | 1.4.3.4 | Integration | 2d | 2002-09-18 | 2002-09-19 | 94, 95, 93 |  |  | 43d |  | start no earlier than 2002-07-25 | Sib | 16h |  |
| 98 | 1.5 | **Navigation Hardware & Testing** | 53d | 2002-09-02 A | 2002-11-13 |  | 2% | 52.12d | 4d |  |  | Hans | 1159.2h | 11.07h |
| 99 | 1.5.1 | **Deep Water testing of USBL** | 38d | 2002-09-02 | 2002-10-23 |  |  |  | 4d | 0d |  | Hans | 467.2h |  |
| 100 | 1.5.1.1 | Tank testing | 18d | 2002-09-02 | 2002-09-25 |  |  |  | 4d | 0d | start no earlier than 2002-09-01 | Hans [30%] | 43.2h |  |
| 101 | 1.5.1.2 | At Sea Testing | 20d | 2002-09-26 | 2002-10-23 | 100 |  |  | 4d |  |  | Hans [75%] | 120h |  |
| 102 | 1.5.2 | **Deep Water Testing of LBL Fish Mode** | 15d | 2002-10-24 | 2002-11-13 | 99 |  |  | 4d |  |  | Hans | 240h |  |
| 103 | 1.5.2.1 | Tank Testing | 10d | 2002-10-24 | 2002-11-06 |  |  |  | 4d | 0d | start no earlier than 2002-09-09 | Hans | 80h |  |
| 104 | 1.5.2.2 | At Sea Testing | 5d | 2002-11-07 | 2002-11-13 | 103 |  |  | 4d |  |  | Hans | 40h |  |
| 105 | 1.5.3 | Radio Range for modems | 3d | 2002-09-06 | 2002-09-10 |  |  |  | 50d |  | start no earlier than 2002-09-06 | Drew [50%] | 12h |  |
| 106 | 1.5.4 | RDF Ranging | 3d | 2002-09-09 | 2002-09-11 |  |  |  | 48d | 0d | start no earlier than 2002-09-07 | Drew [50%] | 12h |  |
| 107 | 1.5.5 | Eval Zephyr RDF capability | 1d | 2002-09-12 A | 2002-09-12 A | 106 | 100% |  |  |  |  | Drew [50%] | 4h | 4h |
| 109 | 1.6 | **Fairings / Vehicle Mechanical Structure** | 81d | 2002-03-15 A | 2002-07-05 |  | 5% | 76.81d | 97d |  |  | Drew | 3268h | 217.44h |
| 110 | 1.6.1 | **L&R System Interface** | 81d | 2002-03-15 A | 2002-07-05 |  | 18% | 66.51d | 97d |  |  | Drew | 1028h | 183.96h |
| 111 | 1.6.1.1 | Prelim Concept w/ Brook ocean | 5d | 2002-03-15 A | 2002-03-21 A |  | 100% |  |  |  |  | Farley | 40h | 40h |
| 112 | 1.6.1.2 | Concept Design Review / Decision | 5.5d | 2002-03-22 A | 2002-05-24 | 111 | 9% | 5d | 127d |  |  | Farley | 44h | 4h |
| 113 | 1.6.1.3 | Design L&R Interface | 10d | 2002-05-27 | 2002-06-07 |  |  |  | 97d | 0d | start no earlier than 2002-05-27 | Farley | 80h |  |
| 114 | 1.6.1.4 | Build Interface | 10d | 2002-06-10 | 2002-06-21 | 113 |  |  | 97d | 0d |  | Shop | 80h |  |
| 115 | 1.6.1.5 | Assemble Interface | 5d | 2002-06-24 | 2002-06-28 | 114 |  |  | 97d | 0d |  | ME TECH | 40h |  |
| 116 | 1.6.1.6 | L&R test plan | 4d | 2002-05-27 | 2002-05-30 |  |  |  | 118d | 21d | start no earlier than 2002-05-26 | Drew | 32h |  |
| 117 | 1.6.1.7 | Integrate and Test L&R Interface | 5d | 2002-07-01 | 2002-07-05 | 116, 115 |  |  | 97d |  |  | Farley | 40h |  |
| 118 | 1.6.1.8 | Evaluate Single Point lift | 3d | 2002-05-06 A | 2002-05-08 A |  | 100% |  |  |  | start no earlier than 2002-05-04 | Drew | 24h | 24h |

| ID | WBS | Task | Duration | Start | Finish | Predecessors | Total slack | Free slack | Constraint | Resources | Work |
| --- | --- | --- | --- | --- | --- | --- | --- | --- | --- | --- | --- |
| 119 | 1.6.2 | **Joining Ring/Systems** | 37d | 2002-05-10 | 2002-07-01 |  | 101d |  |  | Drew | 592h |
| 120 | 1.6.2.1 | Evaluate joining ring systems | 2d | 2002-05-10 | 2002-05-13 |  | 86d | 0d | start no earlier than 2002-05-10 | Farley | 16h |
| 121 | 1.6.2.2 | Review Concept | 1d | 2002-05-14 | 2002-05-14 | 120 | 86d | 0d |  | Farley | 8h |
| 122 | 1.6.2.3 | Final Design | 15d | 2002-05-15 | 2002-06-04 | 121 | 86d | 0d |  | Farley | 120h |
| 123 | 1.6.2.4 | Build | 10d | 2002-06-05 | 2002-06-18 | 122 | 86d | 0d |  | Shop | 80h |
| 124 | 1.6.2.5 | Assemble | 3d | 2002-06-19 | 2002-06-21 | 123 | 86d | 0d |  | ME TECH | 24h |
| 125 | 1.6.2.6 | Test | 3d | 2002-06-24 | 2002-06-26 | 124 | 86d |  |  | Drew | 24h |
| 126 | 1.6.2.7 | Test new joining ring system | 3d | 2002-06-27 | 2002-07-01 |  | 83d |  | start no earlier than 2002-06-27 | Drew | 24h |
| 127 | 1.6.3 | **Deck Handling Equipment** | 15d | 2002-05-20 | 2002-06-07 |  | 117d |  |  | Drew | 376h |
| 128 | 1.6.3.1 | New Cart Design | 5d | 2002-05-20 | 2002-05-24 |  | 127d |  | start no earlier than 2002-05-19 | ME TECH | 40h |
| 129 | 1.6.3.2 | New Lifitng Gear | 5d | 2002-05-27 | 2002-05-31 |  | 122d |  | start no earlier than 2002-05-25 | ME TECH | 40h |
| 130 | 1.6.3.3 | Sphere Lift Mechanism | 10d | 2002-05-21 | 2002-06-03 |  | 121d |  | start no earlier than 2002-05-21 | Farley | 80h |
| 131 | 1.6.3.4 | Eval Single Pt. Lift | 2d | 2002-05-23 | 2002-05-24 |  | 127d |  | start no earlier than 2002-05-23 | Drew | 16h |
| 132 | 1.6.3.5 | Lifting I beam in Lab | 5d | 2002-05-30 | 2002-06-05 |  | 119d |  | start no earlier than 2002-05-30 | ME TECH | 40h |
| 133 | 1.6.3.6 | Cable trays nad outlets in lab ceiling | 5d | 2002-06-03 | 2002-06-07 |  | 117d |  | start no earlier than 2002-06-03 | ME TECH | 40h |
| 134 | 1.6.4 | **Sensor & Payload Mounts** | 7d | 2002-05-20 | 2002-05-28 |  | 117d | 8d |  | Drew | 128h |
| 135 | 1.6.4.1 | Antennaes | 5d | 2002-05-20 | 2002-05-24 |  | 109d |  | start no earlier than 2002-05-18 | Drew | 40h |
| 136 | 1.6.4.2 | ORE & various equip | 4d | 2002-05-23 | 2002-05-28 |  | 107d |  | start no earlier than 2002-05-23 | Drew | 32h |
| 137 | 1.6.5 | **Buoyancy** | 10d | 2002-05-22 | 2002-06-04 |  | 112d | 3d |  | Drew | 200h |
| 138 | 1.6.5.1 | Tailcone Foam Pack Specification | 5d | 2002-05-22 | 2002-05-28 |  | 102d | 0d | start no earlier than 2002-05-22 | Farley | 40h |
| 139 | 1.6.5.2 | Tailcone foam machining | 5d | 2002-05-29 | 2002-06-04 | 138 | 102d |  |  | Farley | 40h |
| 140 | 1.6.5.3 | Modular trim / ballast systems concept | 5d | 2002-05-22 | 2002-05-28 |  | 107d |  | start no earlier than 2002-05-22 | Rob | 40h |
| 141 | 1.6.6 | **Fairing Build** | 13d | 2002-06-10 | 2002-06-26 | 134, 137 | 104d |  |  | Drew | 296h |
| 142 | 1.6.6.1 | Noes section (2 plus 1 spare) | 8d | 2002-06-10 | 2002-06-19 |  | 109d |  | start no earlier than 2002-06-10 | ME TECH | 64h |
| 143 | 1.6.6.2 | Midboady (2 plus 1 spare) | 8d | 2002-06-13 | 2002-06-24 |  | 106d |  | start no earlier than 2002-06-13 | ME TECH | 64h |
| 144 | 1.6.6.3 | Tail section (2 plus 1 spare) | 8d | 2002-06-17 | 2002-06-26 |  | 104d |  | start no earlier than 2002-06-17 | ME TECH | 64h |

| ID | WBS | Task | Duration | Start | Finish | Predecessors | Total slack | Free slack | Constraint | Resources | Work |
| --- | --- | --- | --- | --- | --- | --- | --- | --- | --- | --- | --- |
| 146 | 1.7 | **Software** | 107d | 2002-06-24 | 2002-11-19 |  | 0d |  |  | Hans | 3356h |
| 147 | 1.7.1 | Change supervisor so drivers run all the time | 3d | 2002-09-02 | 2002-09-04 |  | 50d | 0d | start no earlier than 2002-09-02 | Hans [50%] | 12h |
| 148 | 1.7.2 | Chang logging to convert files to MATLAB | 4d | 2002-09-05 | 2002-09-10 | 147 | 50d |  |  | Hans [50%] | 16h |
| 149 | 1.7.3 | **OS Upgrade** | 6d | 2002-09-12 | 2002-09-19 |  | 43d |  |  | Sib | 96h |
| 150 | 1.7.3.1 | QNX Upgrade to Neutrino | 3d | 2002-09-12 | 2002-09-16 |  | 43d | 0d | start no earlier than 2002-09-12 | Kent | 24h |
| 151 | 1.7.3.2 | Eval Linux for possible upgrade in future | 3d | 2002-09-17 | 2002-09-19 | 150 | 43d |  |  | Kent | 24h |
| 152 | 1.7.4 | **GUI** | 50d | 2002-07-02 | 2002-09-09 |  | 51d |  |  | Rich | 800h |
| 153 | 1.7.4.1 | gather requirements | 5d | 2002-07-02 | 2002-07-08 |  | 51d | 0d | start no earlier than 2002-07-02 | Rich | 40h |
| 154 | 1.7.4.2 | eval Bluefin GUI | 10d | 2002-07-09 | 2002-07-22 | 153 | 51d | 0d |  | Rich | 80h |
| 155 | 1.7.4.3 | develop GUI plan | 5d | 2002-07-23 | 2002-07-29 | 154 | 51d | 0d |  | Rich | 40h |
| 156 | 1.7.4.4 | Detail GUI development (TBD) | 30d | 2002-07-30 | 2002-09-09 | 155 | 51d |  |  | Rich | 240h |
| 157 | 1.7.5 | Configuration management on vehicle (config files) | 15d | 2002-08-16 | 2002-09-05 |  | 53d |  | start no earlier than 2002-08-16 | Rich | 120h |
| 158 | 1.7.6 | **Controls** | 45d | 2002-06-24 | 2002-08-23 |  | 62d |  |  | Rob | 720h |
| 159 | 1.7.6.1 | depth control improvement (long configs) | 15d | 2002-06-24 | 2002-07-12 |  | 62d | 0d | start no earlier than 2002-06-22 | Rob | 120h |
| 160 | 1.7.6.2 | sway / yaw control coupling (heave/ pitch too) | 10d | 2002-07-15 | 2002-07-26 | 159 | 62d | 0d |  | Rob | 80h |
| 161 | 1.7.6.3 | slow speed dynamics for control | 20d | 2002-07-29 | 2002-08-23 | 160 | 62d |  |  | Rob | 160h |
| 162 | 1.7.7 | **Navigation Software** | 42d | 2002-09-23 | 2002-11-19 |  | 0d |  |  | Hans | 684h |
| 163 | 1.7.7.1 | Document current NAV sys | 4d | 2002-09-23 | 2002-09-26 |  | 0d |  | start no earlier than 2002-09-23 | Hans [50%] | 16h |
| 164 | 1.7.7.2 | Streamline current nav architecture | 8d | 2002-09-27 | 2002-10-08 | 163 | 0d |  |  | Hans [50%] | 32h |
| 165 | 1.7.7.3 | Single beacon homing | 15d | 2002-10-09 | 2002-10-29 | 164 | 0d |  |  | Hans [50%] | 60h |
| 166 | 1.7.7.4 | Single beacon LBL | 15d | 2002-10-30 | 2002-11-19 | 165 | 0d |  |  | Hans | 120h |
| 167 | 1.7.7.5 | DVL driver enhancements for PD5 | 15d | 2002-10-09 | 2002-10-29 | 164 | 15d |  |  | Rob | 120h |
| 168 | 1.7.8 | **Intra-vehicle Comms** | 4d | 2002-10-01 | 2002-10-04 |  | 32d |  |  | Sib | 52h |
| 169 | 1.7.8.1 | set up socket code (for reconnects) | 3d | 2002-10-01 | 2002-10-03 |  | 32d | 0d | start no earlier than 2002-10-01 | Hans [50%] | 12h |
| 170 | 1.7.8.2 | briding over wireless | 1d | 2002-10-04 | 2002-10-04 | 169 | 32d |  |  | Sib | 8h |

| ID | WBS | Task | Duration | Start | Finish | Predecessors | Total slack | Free slack | Constraint | Resources | Work |
| --- | --- | --- | --- | --- | --- | --- | --- | --- | --- | --- | --- |
| 172 | 1.8 | **Vehicle Integration and Test** | 40d | 2002-06-10 | 2002-08-02 |  | 76d | 0d |  | Hans | 624h |
| 173 | 1.8.1 | Tailcone Assembly | 5d | 2002-06-10 | 2002-06-14 |  | 86d | 0d | start no earlier than 2002-06-08 | Hans [50%] | 20h |
| 174 | 1.8.2 | Tailcone Test | 4d | 2002-06-17 | 2002-06-20 | 173 | 86d | 10d |  | Sib [50%] | 16h |
| 175 | 1.8.3 | Battery Midbody Integration | 5d | 2002-06-17 | 2002-06-21 |  | 81d | 0d | start no earlier than 2002-06-17 | Hans [50%] | 20h |
| 176 | 1.8.4 | Battery Midbody Test | 4d | 2002-06-24 | 2002-06-27 | 175 | 81d | 5d |  | Sib [50%] | 16h |
| 177 | 1.8.5 | ALTEX Nose Payload Assembly/Upgrade | 5d | 2002-06-17 | 2002-06-21 |  | 76d | 0d | start no earlier than 2002-06-17 | Drew | 40h |
| 178 | 1.8.6 | Science Payload Assembly | 6d | 2002-06-24 | 2002-07-01 | 177 | 76d | 0d | start no earlier than 2002-06-07 |  |  |
| 179 | 1.8.7 | Payload Test | 3d | 2002-07-02 | 2002-07-04 | 178 | 76d | 0d |  | Drew | 24h |
| 180 | 1.8.8 | Integrated Vehcile Deck Assembly | 2d | 2002-07-05 | 2002-07-08 | 174, 176, 179 | 76d | 0d |  | Drew | 16h |
| 181 | 1.8.9 | Vehicle Ballasting | 1d | 2002-07-09 | 2002-07-09 | 180 | 76d | 0d |  | Drew | 8h |
| 182 | 1.8.10 | Integrated Vehicle Deck Test | 3d | 2002-07-10 | 2002-07-12 | 181 | 76d | 0d |  | Drew | 24h |
| 183 | 1.8.11 | Integrated Vehicle Tank Test | 5d | 2002-07-15 | 2002-07-19 | 182 | 76d | 0d |  | Drew | 40h |
| 184 | 1.8.12 | Integrated Vehicle Sea Trials | 10d | 2002-07-22 | 2002-08-02 | 183 | 76d |  |  | Drew | 80h |
| 186 | 1.9 | **CTD Science Payload Core** | 33d? | 2002-06-20 | 2002-08-05 |  | 76d |  |  | Drew | 504h |
| 187 | 1.9.1 | Repair/Replace nose fairing | 3d | 2002-06-20 | 2002-06-24 |  | 157d | 0d | start no earlier than 2002-06-20 | ME TECH | 24h |
| 188 | 1.9.2 | recable Dcon to comms and pwr bus | 8d | 2002-06-21 | 2002-07-02 |  | 132d | 0d | start no earlier than 2002-06-21 | EE TECH | 64h |
| 189 | 1.9.3 | Design HS2 Mount | 2d | 2002-06-25 | 2002-06-26 | 187 | 157d | 0d |  | ME TECH | 16h |
| 190 | 1.9.4 | Build HS2 Mount | 2d | 2002-06-27 | 2002-06-28 | 189 | 157d | 0d |  | ME TECH | 16h |
| 191 | 1.9.5 | Assembly HS2 Mount | 2d | 2002-07-01 | 2002-07-02 | 190 | 157d |  |  | ME TECH | 16h |
| 192 | 1.9.6 | Write test driver HS2 | 5d | 2002-06-27 | 2002-07-03 |  | 156d |  | start no earlier than 2002-06-27 | Rich | 40h |
| 193 | 1.9.7 | Eval Foam buoyancy cooridnate 1500 M version | 5d | 2002-06-28 | 2002-07-04 |  | 155d |  | start no earlier than 2002-06-28 | Farley | 40h |
| 194 | 1.9.8 | repair flow sensor #2 | 3d | 2002-07-03 | 2002-07-05 | 188 | 132d |  |  | EE TECH | 24h |
| 195 | 1.9.9 | test integrated CTD Payload | 1d? | 2002-08-05 | 2002-08-05 | 194, 172 | 76d |  |  |  |  |
| 197 | 1.10 | **CTD Extension for Ryan/Haddock** | 21d | 2002-06-03 | 2002-07-01 |  | 101d |  |  | Drew | 488h |
| 198 | 1.10.1 | Design LISST pump assy | 4d | 2002-06-03 | 2002-06-06 |  | 101d | 0d | start no earlier than 2002-06-03 | Drew [50%] | 16h |
| 199 | 1.10.2 | Fab LISST pump assy | 5d | 2002-06-07 | 2002-06-13 | 198 | 104d | 0d |  | Shop | 40h |
| 200 | 1.10.3 | Assy LISST pump into vehicle | 2d | 2002-06-14 | 2002-06-17 | 199 | 104d | 3d |  | ME TECH | 16h |
| 201 | 1.10.4 | Design LISST mount | 5d | 2002-06-07 | 2002-06-13 | 198 | 101d | 0d |  | Farley | 40h |
| 202 | 1.10.5 | Fab LISST Mount | 5d | 2002-06-14 | 2002-06-20 | 201 | 101d | 0d |  | Shop | 40h |
| 203 | 1.10.6 | Assy LISST mount | 2d | 2002-06-21 | 2002-06-24 | 200, 202 | 101d | 0d |  | ME TECH | 16h |
| 204 | 1.10.7 | Cable LISST to Dcon | 1d | 2002-06-25 | 2002-06-25 | 203 | 105d |  |  | EE TECH | 8h |
| 205 | 1.10.8 | Write Test Driver for LISST | 5d | 2002-06-25 | 2002-07-01 | 203 | 101d |  |  | Rich | 40h |
| 206 | 1.10.9 | Design Bathypho mount | 4d | 2002-06-05 | 2002-06-10 |  | 105d | 0d | start no earlier than 2002-06-05 | Drew [50%] | 16h |
| 207 | 1.10.10 | Fab Bathypho mount | 5d | 2002-06-11 | 2002-06-17 | 206 | 105d | 0d |  | ME TECH | 40h |
| 208 | 1.10.11 | Assy Bathypho mount | 2d | 2002-06-18 | 2002-06-19 | 207 | 105d | 0d |  | ME TECH | 16h |
| 209 | 1.10.12 | Cable Bathypho to Dcon | 1d | 2002-06-20 | 2002-06-20 | 208 | 105d | 0d |  | EE TECH | 8h |
| 210 | 1.10.13 | Retest driver for Bathypho (already written) | 3d | 2002-06-21 | 2002-06-25 | 209 | 105d |  |  | Rich | 24h |
| 212 | 1.11 | Ryan / Haddock Cruise Prep | 14d | 2002-07-29 | 2002-08-15 |  | 68d |  | start no earlier than 2002-07-27 | Hans | 112h |
