# Dorado2002revD

Schedule from MS Project, 2002-03-15 to 2002-11-19, A marks actual dates.
KEE Systems

## Calendars

- Standard: Mon-Fri 08:00-12:00, 13:00-17:00; Sat-Sun off.

## Resources

| Resource |
| --- |
| Hans |
| Drew |
| Sib |
| Farley |
| ME |
| Rob |
| Rich |
| Craig |
| Kent |
| ME TECH |
| EE TECH |
| Shop |
| Kiwi |

## Schedule

| ID | WBS | Task | Duration | Start | Finish | Predecessors | Complete | Remaining | Baseline start | Baseline finish | Baseline duration | Total slack | Free slack | Constraint | Resources | Work | Actual work |
| --- | --- | --- | --- | --- | --- | --- | --- | --- | --- | --- | --- | --- | --- | --- | --- | --- | --- |
| 1 | 1 | **Dorado Program** | 178d? | 2002-03-15 A | 2002-11-19 |  | 9% | 161.31d? | 2002-03-15 | 2002-11-19 | 178d? | 0d |  |  |  | 15896.4h | 1841.54h |
| 3 | 1.1 | **Propulsion** | 133d? | 2002-03-15 A | 2002-09-17 |  | 12% | 116.86d? | 2002-05-02 | 2002-09-17 | 99d | 45d |  |  |  | 550h | 94h |
| 4 | 1.1.1 | **Articulated Tail** | 83d | 2002-05-20 A | 2002-09-11 |  | 38% | 51.18d | 2002-05-02 | 2002-09-11 | 95d | 45d | 0d |  |  | 212h | 92h |
| 5 | 1.1.1.1 | Design & Build New Electronics Housing | 23d | 2002-05-20 A | 2002-06-19 |  | 50% | 11.5d | 2002-05-02 | 2002-05-15 | 10d | 105d |  | start no earlier than 2002-05-02 | Farley | 184h | 92h |
| 6 | 1.1.1.2 | New Linear Actuator Scheme | 7d | 2002-09-03 | 2002-09-11 |  |  |  | 2002-09-03 | 2002-09-11 | 7d | 45d |  | start no earlier than 2002-09-03 | Hans [50%] | 28h |  |
| 7 | 1.1.2 | **Drive Electronics** | 41d | 2002-05-27 A | 2002-07-22 |  |  | 41d | 2002-05-06 | 2002-06-06 | 24d | 81d | 0d |  |  | 136h |  |
| 8 | 1.1.2.1 | Integrate New Electroincs | 24d | 2002-06-19 A | 2002-07-22 |  |  | 24d | 2002-05-06 | 2002-06-06 | 24d | 81d |  | start no earlier than 2002-05-05 | Sib [50%] | 96h |  |
| 9 | 1.1.2.2 | Cabling | 5d | 2002-05-27 | 2002-05-31 |  |  |  | 2002-05-27 | 2002-05-31 | 5d | 117d |  | start no earlier than 2002-05-27 | EE TECH | 40h |  |
| 10 | 1.1.3 | Integrate New Tail Into fairing | 5d | 2002-07-23 | 2002-07-29 | 7 |  |  | 2002-06-07 | 2002-06-13 | 5d | 81d |  |  | Farley | 40h |  |
| 11 | 1.1.4 | Tailcone - Bench Stand Design and Fab | 3d | 2002-05-27 | 2002-05-29 |  |  |  | 2002-05-27 | 2002-05-29 | 3d | 124d |  | start no earlier than 2002-05-27 | ME TECH | 24h |  |
| 12 | 1.1.5 | Buoyancy Check / Test | 1d | 2002-06-14 A | 2002-06-14 A | 10 | 100% |  | 2002-06-14 | 2002-06-14 | 1d |  |  |  | Drew [25%] | 2h | 2h |
| 13 | 1.1.6 | Test Plan | 5d | 2002-06-14 | 2002-06-20 |  |  |  | 2002-06-14 | 2002-06-20 | 5d | 108d |  | start no earlier than 2002-06-14 | Rob | 40h |  |
| 14 | 1.1.7 | Replace foam with 4500 M | 20d | 2002-06-17 | 2002-07-12 |  |  |  |  |  |  | 92d |  | start no earlier than 2002-06-17 | Drew [15%] | 24h |  |
| 15 | 1.1.8 | Compensator design / purchase | 1d? | 2002-03-15 | 2002-03-15 |  |  |  |  |  |  | 177d |  |  |  |  |  |
| 16 | 1.1.9 | **Tailcone Documetation** | 4d | 2002-09-12 | 2002-09-17 | 7, 4 |  |  | 2002-09-12 | 2002-09-17 | 4d | 45d |  |  |  | 72h |  |
| 17 | 1.1.9.1 | Mechanical | 3d | 2002-09-12 | 2002-09-16 |  |  |  | 2002-09-12 | 2002-09-16 | 3d | 46d |  |  | Farley | 24h |  |
| 18 | 1.1.9.2 | Electrical | 2d | 2002-09-12 | 2002-09-13 |  |  |  | 2002-09-12 | 2002-09-13 | 2d | 47d |  | start no earlier than 2002-09-02 | Sib | 16h |  |
| 19 | 1.1.9.3 | Software | 4d | 2002-09-12 | 2002-09-17 |  |  |  | 2002-09-12 | 2002-09-17 | 4d | 45d |  | start no earlier than 2002-09-04 | Sib | 32h |  |
| 21 | 1.2 | **Power** | 51d? | 2002-04-15 A | 2002-06-24 |  | 9% | 46.25d? | 2002-04-15 | 2002-06-24 | 51d? | 106d |  |  | Hans | 1865.2h | 156.57h |
| 22 | 1.2.1 | **Battery Chemistry** | 29d | 2002-04-15 A | 2002-05-23 |  | 15% | 24.7d | 2002-04-15 | 2002-05-23 | 29d | 125d |  |  | Hans | 472h | 54.55h |
| 23 | 1.2.1.1 | Check life on current Ag-Zn batteries | 4d | 2002-04-15 A | 2002-04-18 |  | 66% | 1.36d | 2002-04-15 | 2002-04-18 | 4d | 122d | 3d | start no earlier than 2002-04-13 | Hans [50%] | 16h | 10.56h |
| 24 | 1.2.1.2 | Trade study to review Batt Chems | 3d | 2002-04-18 A | 2002-04-22 |  | 80% | 0.6d | 2002-04-18 | 2002-04-22 | 3d | 120d | 1d | start no earlier than 2002-04-18 | Hans [50%] | 12h | 9.6h |
| 25 | 1.2.1.3 | Thermal Analysis of Battery Pack | 5d | 2002-04-17 | 2002-04-23 |  |  |  | 2002-04-17 | 2002-04-23 | 5d | 119d | 0d | start no earlier than 2002-04-17 | Kiwi | 40h |  |
| 26 | 1.2.1.4 | Design Review of Batt Chems | 1d | 2002-04-24 | 2002-04-24 | 23, 24, 25 |  |  | 2002-04-24 | 2002-04-24 | 1d | 119d | 0d |  | Hans | 8h |  |
| 27 | 1.2.1.5 | Purchase Batteries | 1d | 2002-04-25 | 2002-04-25 | 26 |  |  | 2002-04-25 | 2002-04-25 | 1d | 125d | 0d |  | Hans [50%] | 4h |  |
| 28 | 1.2.1.6 | Assemble Batteries | 5d | 2002-04-26 | 2002-05-02 | 27 |  |  | 2002-04-26 | 2002-05-02 | 5d | 125d | 0d |  | EE TECH | 40h |  |
| 29 | 1.2.1.7 | Test Batteries | 15d | 2002-05-03 | 2002-05-23 | 28 |  |  | 2002-05-03 | 2002-05-23 | 15d | 125d | 11d |  | EE TECH | 120h |  |

| ID | WBS | Task | Duration | Start | Finish | Predecessors | Complete | Remaining | Baseline start | Baseline finish | Baseline duration | Total slack | Free slack | Constraint | Resources | Work | Actual work |
| --- | --- | --- | --- | --- | --- | --- | --- | --- | --- | --- | --- | --- | --- | --- | --- | --- | --- |
| 30 | 1.2.2 | **Battery Housing** | 34d | 2002-04-25 A | 2002-06-11 | 26 | 12% | 30d | 2002-04-25 | 2002-06-11 | 34d | 115d |  |  | Hans | 544h | 64h |
| 31 | 1.2.2.1 | Design | 10d | 2002-05-01 | 2002-05-14 |  |  |  | 2002-05-01 | 2002-05-14 | 10d | 115d | 0d | start no earlier than 2002-05-01 | Craig | 80h |  |
| 32 | 1.2.2.2 | Build | 15d | 2002-05-15 | 2002-06-04 | 31 |  |  | 2002-05-15 | 2002-06-04 | 15d | 115d | 0d |  | ME TECH | 120h |  |
| 33 | 1.2.2.3 | Test | 5d | 2002-06-05 | 2002-06-11 | 32 |  |  | 2002-06-05 | 2002-06-11 | 5d | 115d |  |  | Craig | 40h |  |
| 34 | 1.2.2.4 | Spec Interconnects | 4d | 2002-04-25 A | 2002-04-30 A |  | 100% |  | 2002-04-25 | 2002-04-30 | 4d |  |  | start no earlier than 2002-03-28 | Sib | 32h | 32h |
| 35 | 1.2.3 | **Battery Electronics** | 29d? | 2002-05-01 | 2002-06-10 | 26, 34 |  |  | 2002-05-01 | 2002-06-10 | 29d? | 114d | 0d |  | Sib | 386h |  |
| 36 | 1.2.3.1 | Concept Design | 5d | 2002-05-01 | 2002-05-07 |  |  |  | 2002-05-01 | 2002-05-07 | 5d | 122d | 0d | start no earlier than 2002-04-22 | Sib | 40h |  |
| 37 | 1.2.3.2 | Design Review | 2d | 2002-05-08 | 2002-05-09 | 36 |  |  | 2002-05-08 | 2002-05-09 | 2d | 122d | 0d |  | Sib | 16h |  |
| 38 | 1.2.3.3 | Final Design | 11d | 2002-05-10 | 2002-05-24 | 37 |  |  | 2002-05-10 | 2002-05-24 | 11d | 122d | 0d | start no earlier than 2002-05-01 | Sib [75%] | 66h |  |
| 39 | 1.2.3.4 | Build | 1d | 2002-05-27 | 2002-05-27 | 38 |  |  | 2002-05-27 | 2002-05-27 | 1d | 122d | 0d |  | EE TECH | 8h |  |
| 40 | 1.2.3.5 | Assemble | 1d | 2002-05-28 | 2002-05-28 | 39 |  |  | 2002-05-28 | 2002-05-28 | 1d | 122d | 0d |  | EE TECH | 8h |  |
| 41 | 1.2.3.6 | Test | 1d | 2002-05-29 | 2002-05-29 | 40 |  |  | 2002-05-29 | 2002-05-29 | 1d | 122d |  |  | EE TECH | 8h |  |
| 42 | 1.2.3.7 | Spec Misc Electronics (Contingency) | 1d? | 2002-06-10 | 2002-06-10 | 29 |  |  | 2002-06-10 | 2002-06-10 | 1d? | 114d |  | start no earlier than 2002-06-10 | Sib | 8h |  |
| 43 | 1.2.4 | **Battery Charging** | 2d | 2002-06-11 | 2002-06-12 | 26, 35 |  |  | 2002-06-11 | 2002-06-12 | 2d | 114d |  |  | Hans | 23.2h |  |
| 44 | 1.2.4.1 | Spec Charging Analysis | 2d | 2002-06-11 | 2002-06-12 |  |  |  | 2002-06-11 | 2002-06-12 | 2d | 114d |  |  | Hans [20%] | 3.2h |  |
| 45 | 1.2.4.2 | Order Charging Equip as Required | 1d | 2002-06-11 | 2002-06-11 |  |  |  | 2002-06-11 | 2002-06-11 | 1d | 115d |  |  | Hans [50%] | 4h |  |
| 46 | 1.2.5 | AUV Power Systems Meeting | 4d | 2002-06-19 | 2002-06-24 |  |  |  | 2002-06-19 | 2002-06-24 | 4d | 106d |  | start no earlier than 2002-06-19 | Hans | 32h |  |
| 48 | 1.3 | **Cabling and Connectors** | 42d | 2002-04-25 A | 2002-06-21 | 26 | 41% | 24.61d | 2002-04-25 | 2002-06-21 | 42d | 107d |  |  | Drew | 516h | 217.58h |
| 49 | 1.3.1 | Spec Main Power / Comms Cable&Connectors/Penetrators | 13d | 2002-04-25 A | 2002-05-13 |  | 50% | 6.5d | 2002-04-25 | 2002-05-13 | 13d | 124.66d | 0d |  | Hans [50%] | 52h | 26h |
| 50 | 1.3.2 | Spec Charging Connector | 4d | 2002-05-14 | 2002-05-17 | 49 |  |  | 2002-05-14 | 2002-05-17 | 4d | 132d |  |  | Hans [25%] | 8h |  |
| 51 | 1.3.3 | Spec Tailcone Comms Cable&Connector/Penetrator | 3d | 2002-04-25 A | 2002-04-29 |  | 80% | 0.6d | 2002-04-25 | 2002-04-29 | 3d | 134.66d | 10d | start no earlier than 2002-03-18 | Sib | 24h | 19.2h |
| 52 | 1.3.4 | Spec Science Instrument Connector | 2d | 2002-04-25 A | 2002-04-26 A |  | 100% |  | 2002-04-25 | 2002-04-26 | 2d |  |  | start no earlier than 2002-04-24 | Drew [25%] | 4h | 4h |
| 53 | 1.3.5 | Spec DVL and parosci Connectors / Penetrator | 1d | 2002-04-29 A | 2002-04-29 A | 52 | 100% |  | 2002-04-29 | 2002-04-29 | 1d |  |  |  | Drew [25%] | 2h | 2h |
| 54 | 1.3.6 | Spec RF/Acoustic/Emer location Connect & Penetrators | 1d | 2002-04-30 A | 2002-04-30 A | 53 | 100% |  | 2002-04-30 | 2002-04-30 | 1d |  |  |  | Drew [50%] | 4h | 4h |
| 55 | 1.3.7 | Spec On/Off Connector/Penetrator | 1d | 2002-05-01 A | 2002-05-01 A | 54 | 100% |  | 2002-05-01 | 2002-05-01 | 1d |  |  |  | Drew [25%] | 2h | 2h |
| 56 | 1.3.8 | Test ability of 100 MB/s thrugh current ALTEX Cable | 2d | 2002-05-21 A | 2002-05-22 A |  | 100% |  | 2002-05-21 | 2002-05-22 | 2d |  |  | start no earlier than 2002-05-21 | Drew | 16h | 16h |
| 57 | 1.3.9 | Order Connectors | 2d | 2002-05-14 A | 2002-05-15 | 49, 51, 55 | 33% | 1.34d | 2002-05-14 | 2002-05-15 | 2d | 124d | 17d |  | Drew | 16h | 5.28h |

| ID | WBS | Task | Duration | Start | Finish | Predecessors | Complete | Remaining | Baseline start | Baseline finish | Baseline duration | Total slack | Free slack | Constraint | Resources | Work | Actual work |
| --- | --- | --- | --- | --- | --- | --- | --- | --- | --- | --- | --- | --- | --- | --- | --- | --- | --- |
| 58 | 1.3.10 | **Tail to MVC** | 1d | 2002-05-09 | 2002-05-09 |  |  |  | 2002-05-09 | 2002-05-09 | 1d | 128d |  |  | Drew | 12h |  |
| 59 | 1.3.10.1 | Section Interconnect | 1d | 2002-05-09 | 2002-05-09 |  |  |  | 2002-05-09 | 2002-05-09 | 1d | 128d | 21d | start no earlier than 2002-05-09 | Drew [50%] | 4h |  |
| 60 | 1.3.11 | Documetation package on Connectors and Cabling | 10d | 2002-06-10 | 2002-06-21 | 57, 59 |  |  | 2002-06-10 | 2002-06-21 | 10d | 107d |  | start no earlier than 2002-06-10 | Drew [50%] | 40h |  |
| 62 | 1.4 | **Main Vehicle Computer** | 135d | 2002-03-15 A | 2002-09-19 |  | 33% | 90.68d | 2002-03-15 | 2002-09-19 | 135d | 43d |  |  | Sib | 3454h | 1144.88h |
| 63 | 1.4.1 | **Electronics** | 59d | 2002-03-15 A | 2002-06-05 |  | 45% | 32.16d | 2002-03-15 | 2002-06-05 | 59d | 119d |  |  | Sib | 1510h | 691.55h |
| 64 | 1.4.1.1 | Spec PC 104 Stack | 2d | 2002-03-15 A | 2002-03-18 A |  | 100% |  | 2002-03-15 | 2002-03-18 | 2d |  |  |  | Sib | 16h | 16h |
| 65 | 1.4.1.2 | Order PC 104 Stack | 2d | 2002-03-19 A | 2002-05-07 | 64 | 40% | 1.2d | 2002-03-19 | 2002-05-07 | 2d | 138.8d | 0d |  | Sib | 16h | 6.4h |
| 66 | 1.4.1.3 | Assemble PC 104 Stack | 2d | 2002-05-07 | 2002-05-09 | 65 |  |  | 2002-05-07 | 2002-05-09 | 2d | 138.8d |  |  | EE TECH | 16h |  |
| 67 | 1.4.1.4 | Develop latency test/budget for MVC | 4d | 2002-05-13 | 2002-05-16 |  |  |  | 2002-05-13 | 2002-05-16 | 4d | 133d |  | start no earlier than 2002-05-11 | Sib [50%] | 16h |  |
| 68 | 1.4.1.5 | **Power Board** | 23d | 2002-04-28 A | 2002-05-29 | 26 | 50% | 11.5d | 2002-04-28 | 2002-05-29 | 23d | 114d | 70d |  | Sib | 282h | 133h |
| 69 | 1.4.1.5.1 | Specify | 4d | 2002-04-28 A | 2002-05-02 A |  | 100% |  | 2002-04-28 | 2002-05-02 | 4d |  |  | start no earlier than 2002-05-06 | Sib [50%] | 16h | 16h |
| 70 | 1.4.1.5.2 | Design | 15d | 2002-05-03 A | 2002-05-23 | 69 | 50% | 7.5d | 2002-05-03 | 2002-05-23 | 15d | 114d | 0d |  | Sib [75%] | 90h | 45h |
| 71 | 1.4.1.5.3 | Order | 1d | 2002-05-24 | 2002-05-24 | 70 |  |  | 2002-05-24 | 2002-05-24 | 1d | 114d | 0d |  | Sib | 8h |  |
| 72 | 1.4.1.5.4 | Build | 2d | 2002-05-27 | 2002-05-28 | 71 |  |  | 2002-05-27 | 2002-05-28 | 2d | 114d | 0d |  | EE TECH | 16h |  |
| 73 | 1.4.1.5.5 | Test | 1d | 2002-05-29 | 2002-05-29 | 72 |  |  | 2002-05-29 | 2002-05-29 | 1d | 114d |  |  | EE TECH | 8h |  |
| 74 | 1.4.1.6 | **RF Modem** | 44d | 2002-03-15 A | 2002-05-15 |  | 71% | 12.57d | 2002-03-15 | 2002-05-15 | 44d | 134d |  |  | Drew | 376h | 271.43h |
| 75 | 1.4.1.6.1 | Evaluate Data-link vs Freewave | 5d | 2002-03-15 A | 2002-03-21 A |  | 100% |  | 2002-03-15 | 2002-03-21 | 5d |  |  |  | Drew [50%] | 20h | 20h |
| 76 | 1.4.1.6.2 | Purchase | 2d | 2002-05-14 | 2002-05-15 |  |  |  | 2002-05-14 | 2002-05-15 | 2d | 134d |  | start no earlier than 2002-05-14 | Drew [25%] | 4h |  |
| 77 | 1.4.1.7 | **Acoustic Modem** | 2d | 2002-05-17 | 2002-05-20 |  |  |  | 2002-05-17 | 2002-05-20 | 2d | 121d | 77d |  | Hans | 24h |  |
| 78 | 1.4.1.7.1 | Evaluate | 1d | 2002-05-17 | 2002-05-17 |  |  |  | 2002-05-17 | 2002-05-17 | 1d | 121d | 0d | start no earlier than 2002-05-17 | Hans [50%] | 4h |  |
| 79 | 1.4.1.7.2 | Purchase | 1d | 2002-05-20 | 2002-05-20 | 78 |  |  | 2002-05-20 | 2002-05-20 | 1d | 121d |  |  | Hans [50%] | 4h |  |
| 80 | 1.4.1.8 | **GPS** | 15d | 2002-05-16 | 2002-06-05 |  |  |  | 2002-05-16 | 2002-06-05 | 15d | 109d | 65d |  | Drew | 234h |  |
| 81 | 1.4.1.8.1 | Evaluate GPS Position Fix Problem | 10d | 2002-05-16 | 2002-05-29 |  |  |  | 2002-05-16 | 2002-05-29 | 10d | 109d | 0d | start no earlier than 2002-05-16 | Craig | 80h |  |
| 82 | 1.4.1.8.2 | Evaluate GPS Board & Antennae | 4d | 2002-05-30 | 2002-06-04 | 81 |  |  | 2002-05-30 | 2002-06-04 | 4d | 109d | 0d |  | Craig | 32h |  |
| 83 | 1.4.1.8.3 | Purchase GPS Board & Antennae | 1d | 2002-06-05 | 2002-06-05 | 82 |  |  | 2002-06-05 | 2002-06-05 | 1d | 109d |  |  | Drew [25%] | 2h |  |
| 84 | 1.4.1.9 | Eval and Purchase 10/100 Hub | 4d | 2002-03-20 A | 2002-03-25 A |  | 100% |  | 2002-03-20 | 2002-03-25 | 4d |  |  | start no earlier than 2002-03-20 | Sib [25%] | 8h | 8h |
| 85 | 1.4.1.10 | Eval & Purchase AHRS | 1d | 2002-03-15 A | 2002-03-15 A |  | 100% |  | 2002-03-15 | 2002-03-15 | 1d |  |  |  | Drew [25%] | 2h | 2h |
| 86 | 1.4.1.11 | Eval and Purchase LBL Board Set | 4d | 2002-03-15 A | 2002-03-20 A |  | 100% |  | 2002-03-15 | 2002-03-20 | 4d |  |  |  | Hans [25%] | 8h | 8h |
| 87 | 1.4.1.12 | Spec and Purcahse DVL | 5d | 2002-05-14 A | 2002-05-20 |  | 80% | 1d | 2002-05-14 | 2002-05-20 | 5d | 131d |  |  | Rob | 40h | 32h |

| ID | WBS | Task | Duration | Start | Finish | Predecessors | Complete | Remaining | Baseline start | Baseline finish | Baseline duration | Total slack | Free slack | Constraint | Resources | Work | Actual work |
| --- | --- | --- | --- | --- | --- | --- | --- | --- | --- | --- | --- | --- | --- | --- | --- | --- | --- |
| 88 | 1.4.2 | **MVC Housing** | 58d | 2002-03-15 A | 2002-06-04 |  | 17% | 48.06d | 2002-03-15 | 2002-06-04 | 58d | 110d |  |  | Drew | 664h | 98.74h |
| 89 | 1.4.2.1 | Spec Interconnects | 6d | 2002-03-15 A | 2002-03-22 |  | 80% | 1.2d | 2002-03-15 | 2002-03-22 | 6d | 140d | 30d |  | Drew [50%] | 24h | 19.2h |
| 90 | 1.4.2.2 | Design | 5d | 2002-05-06 | 2002-05-10 | 89 |  |  | 2002-05-06 | 2002-05-10 | 5d | 110d | 0d | start no earlier than 2002-05-04 | Farley | 40h |  |
| 91 | 1.4.2.3 | Build/Purchase | 10d | 2002-05-13 | 2002-05-24 | 90 |  |  | 2002-05-13 | 2002-05-24 | 10d | 110d | 0d |  | Shop | 80h |  |
| 92 | 1.4.2.4 | Pressure Test | 2d | 2002-05-27 | 2002-05-28 | 91 |  |  | 2002-05-27 | 2002-05-28 | 2d | 110d | 0d |  | ME TECH | 16h |  |
| 93 | 1.4.2.5 | Electronics Packagin Layout | 5d | 2002-05-29 | 2002-06-04 | 92 |  |  | 2002-05-29 | 2002-06-04 | 5d | 110d | 66d |  | Drew | 40h |  |
| 94 | 1.4.3 | **Documentation Package** | 11d | 2002-09-05 | 2002-09-19 | 93, 80, 77, 68 |  |  | 2002-09-05 | 2002-09-19 | 11d | 43d |  |  | Sib | 200h |  |
| 95 | 1.4.3.1 | Mechanical | 2d | 2002-09-05 | 2002-09-06 |  |  |  | 2002-09-05 | 2002-09-06 | 2d | 50d | 7d | start no earlier than 2002-09-05 | Farley | 16h |  |
| 96 | 1.4.3.2 | Electrical | 8d | 2002-09-05 | 2002-09-16 |  |  |  | 2002-09-05 | 2002-09-16 | 8d | 44d | 1d | start no earlier than 2002-09-05 | Sib | 64h |  |
| 97 | 1.4.3.3 | Software | 2d | 2002-09-16 | 2002-09-17 |  |  |  | 2002-09-16 | 2002-09-17 | 2d | 43d | 0d | start no earlier than 2002-09-16 | Hans | 16h |  |
| 98 | 1.4.3.4 | Integration | 2d | 2002-09-18 | 2002-09-19 | 96, 97, 95 |  |  | 2002-09-18 | 2002-09-19 | 2d | 43d |  | start no earlier than 2002-07-25 | Sib | 16h |  |
| 100 | 1.5 | **Navigation Hardware & Testing** | 53d | 2002-09-02 A | 2002-11-13 |  | 2% | 52.12d | 2002-09-02 | 2002-11-13 | 53d | 4d |  |  | Hans | 1159.2h | 11.07h |
| 101 | 1.5.1 | **Deep Water testing of USBL** | 38d | 2002-09-02 | 2002-10-23 |  |  |  | 2002-09-02 | 2002-10-23 | 38d | 4d | 0d |  | Hans | 467.2h |  |
| 102 | 1.5.1.1 | Tank testing | 18d | 2002-09-02 | 2002-09-25 |  |  |  | 2002-09-02 | 2002-09-25 | 18d | 4d | 0d | start no earlier than 2002-09-01 | Hans [30%] | 43.2h |  |
| 103 | 1.5.1.2 | At Sea Testing | 20d | 2002-09-26 | 2002-10-23 | 102 |  |  | 2002-09-26 | 2002-10-23 | 20d | 4d |  |  | Hans [75%] | 120h |  |
| 104 | 1.5.2 | **Deep Water Testing of LBL Fish Mode** | 15d | 2002-10-24 | 2002-11-13 | 101 |  |  | 2002-10-24 | 2002-11-13 | 15d | 4d |  |  | Hans | 240h |  |
| 105 | 1.5.2.1 | Tank Testing | 10d | 2002-10-24 | 2002-11-06 |  |  |  | 2002-10-24 | 2002-11-06 | 10d | 4d | 0d | start no earlier than 2002-09-09 | Hans | 80h |  |
| 106 | 1.5.2.2 | At Sea Testing | 5d | 2002-11-07 | 2002-11-13 | 105 |  |  | 2002-11-07 | 2002-11-13 | 5d | 4d |  |  | Hans | 40h |  |
| 107 | 1.5.3 | Radio Range for modems | 3d | 2002-09-06 | 2002-09-10 |  |  |  | 2002-09-06 | 2002-09-10 | 3d | 50d |  | start no earlier than 2002-09-06 | Drew [50%] | 12h |  |
| 108 | 1.5.4 | RDF Ranging | 3d | 2002-09-09 | 2002-09-11 |  |  |  | 2002-09-09 | 2002-09-11 | 3d | 49d |  | start no earlier than 2002-09-07 | Drew [50%] | 12h |  |
| 109 | 1.5.5 | Eval Zephyr RDF capability | 1d | 2002-09-12 A | 2002-09-12 A | 108 | 100% |  | 2002-09-12 | 2002-09-12 | 1d |  |  |  | Drew [50%] | 4h | 4h |
| 111 | 1.6 | **Fairings / Vehicle Mechanical Structure** | 81d | 2002-03-15 A | 2002-07-05 |  | 5% | 76.81d | 2002-03-15 | 2002-07-05 | 81d | 97d |  |  | Drew | 3268h | 217.44h |
| 112 | 1.6.1 | **L&R System Interface** | 81d | 2002-03-15 A | 2002-07-05 |  | 18% | 66.51d | 2002-03-15 | 2002-07-05 | 81d | 97d |  |  | Drew | 1028h | 183.96h |
| 113 | 1.6.1.1 | Prelim Concept w/ Brook ocean | 5d | 2002-03-15 A | 2002-03-21 A |  | 100% |  | 2002-03-15 | 2002-03-21 | 5d |  |  |  | Farley | 40h | 40h |
| 114 | 1.6.1.2 | Concept Design Review / Decision | 5.5d | 2002-03-22 A | 2002-05-24 | 113 | 9% | 5d | 2002-03-22 | 2002-05-24 | 5.5d | 127d |  |  | Farley | 44h | 4h |
| 115 | 1.6.1.3 | Design L&R Interface | 10d | 2002-05-27 | 2002-06-07 |  |  |  | 2002-05-27 | 2002-06-07 | 10d | 97d | 0d | start no earlier than 2002-05-27 | Farley | 80h |  |
| 116 | 1.6.1.4 | Build Interface | 10d | 2002-06-10 | 2002-06-21 | 115 |  |  | 2002-06-10 | 2002-06-21 | 10d | 97d | 0d |  | Shop | 80h |  |
| 117 | 1.6.1.5 | Assemble Interface | 5d | 2002-06-24 | 2002-06-28 | 116 |  |  | 2002-06-24 | 2002-06-28 | 5d | 97d | 0d |  | ME TECH | 40h |  |
| 118 | 1.6.1.6 | L&R test plan | 4d | 2002-05-27 | 2002-05-30 |  |  |  | 2002-05-27 | 2002-05-30 | 4d | 118d | 21d | start no earlier than 2002-05-26 | Drew | 32h |  |
| 119 | 1.6.1.7 | Integrate and Test L&R Interface | 5d | 2002-07-01 | 2002-07-05 | 118, 117 |  |  | 2002-07-01 | 2002-07-05 | 5d | 97d |  |  | Farley | 40h |  |
| 120 | 1.6.1.8 | Evaluate Single Point lift | 3d | 2002-05-06 A | 2002-05-08 A |  | 100% |  | 2002-05-06 | 2002-05-08 | 3d |  |  | start no earlier than 2002-05-04 | Drew | 24h | 24h |

| ID | WBS | Task | Duration | Start | Finish | Predecessors | Baseline start | Baseline finish | Baseline duration | Total slack | Free slack | Constraint | Resources | Work |
| --- | --- | --- | --- | --- | --- | --- | --- | --- | --- | --- | --- | --- | --- | --- |
| 121 | 1.6.2 | **Joining Ring/Systems** | 37d | 2002-05-10 | 2002-07-01 |  | 2002-05-10 | 2002-07-01 | 37d | 101d |  |  | Drew | 592h |
| 122 | 1.6.2.1 | Evaluate joining ring systems | 2d | 2002-05-10 | 2002-05-13 |  | 2002-05-10 | 2002-05-13 | 2d | 104d | 0d | start no earlier than 2002-05-10 | Farley | 16h |
| 123 | 1.6.2.2 | Review Concept | 1d | 2002-05-14 | 2002-05-14 | 122 | 2002-05-14 | 2002-05-14 | 1d | 104d | 0d |  | Farley | 8h |
| 124 | 1.6.2.3 | Final Design | 15d | 2002-05-15 | 2002-06-04 | 123 | 2002-05-15 | 2002-06-04 | 15d | 104d | 0d |  | Farley | 120h |
| 125 | 1.6.2.4 | Build | 10d | 2002-06-05 | 2002-06-18 | 124 | 2002-06-05 | 2002-06-18 | 10d | 104d | 0d |  | Shop | 80h |
| 126 | 1.6.2.5 | Assemble | 3d | 2002-06-19 | 2002-06-21 | 125 | 2002-06-19 | 2002-06-21 | 3d | 104d | 0d |  | ME TECH | 24h |
| 127 | 1.6.2.6 | Test | 3d | 2002-06-24 | 2002-06-26 | 126 | 2002-06-24 | 2002-06-26 | 3d | 104d |  |  | Drew | 24h |
| 128 | 1.6.2.7 | Test new joining ring system | 3d | 2002-06-27 | 2002-07-01 |  | 2002-06-27 | 2002-07-01 | 3d | 101d |  | start no earlier than 2002-06-27 | Drew | 24h |
| 129 | 1.6.3 | **Deck Handling Equipment** | 15d | 2002-05-20 | 2002-06-07 |  | 2002-05-20 | 2002-06-07 | 15d | 117d |  |  | Drew | 376h |
| 130 | 1.6.3.1 | New Cart Design | 5d | 2002-05-20 | 2002-05-24 |  | 2002-05-20 | 2002-05-24 | 5d | 127d |  | start no earlier than 2002-05-19 | ME TECH | 40h |
| 131 | 1.6.3.2 | New Lifitng Gear | 5d | 2002-05-27 | 2002-05-31 |  | 2002-05-27 | 2002-05-31 | 5d | 122d |  | start no earlier than 2002-05-25 | ME TECH | 40h |
| 132 | 1.6.3.3 | Sphere Lift Mechanism | 10d | 2002-05-21 | 2002-06-03 |  | 2002-05-21 | 2002-06-03 | 10d | 121d |  | start no earlier than 2002-05-21 | Farley | 80h |
| 133 | 1.6.3.4 | Eval Single Pt. Lift | 2d | 2002-05-23 | 2002-05-24 |  | 2002-05-23 | 2002-05-24 | 2d | 127d |  | start no earlier than 2002-05-23 | Drew | 16h |
| 134 | 1.6.3.5 | Lifting I beam in Lab | 5d | 2002-05-30 | 2002-06-05 |  | 2002-05-30 | 2002-06-05 | 5d | 119d |  | start no earlier than 2002-05-30 | ME TECH | 40h |
| 135 | 1.6.3.6 | Cable trays nad outlets in lab ceiling | 5d | 2002-06-03 | 2002-06-07 |  | 2002-06-03 | 2002-06-07 | 5d | 117d |  | start no earlier than 2002-06-03 | ME TECH | 40h |
| 136 | 1.6.4 | **Sensor & Payload Mounts** | 7d | 2002-05-20 | 2002-05-28 |  | 2002-05-20 | 2002-05-28 | 7d | 117d | 8d |  | Drew | 128h |
| 137 | 1.6.4.1 | Antennaes | 5d | 2002-05-20 | 2002-05-24 |  | 2002-05-20 | 2002-05-24 | 5d | 119d |  | start no earlier than 2002-05-18 | Drew | 40h |
| 138 | 1.6.4.2 | ORE & various equip | 4d | 2002-05-23 | 2002-05-28 |  | 2002-05-23 | 2002-05-28 | 4d | 117d |  | start no earlier than 2002-05-23 | Drew | 32h |
| 139 | 1.6.5 | **Buoyancy** | 10d | 2002-05-22 | 2002-06-04 |  | 2002-05-22 | 2002-06-04 | 10d | 112d | 3d |  | Drew | 200h |
| 140 | 1.6.5.1 | Tailcone Foam Pack Specification | 5d | 2002-05-22 | 2002-05-28 |  | 2002-05-22 | 2002-05-28 | 5d | 112d | 0d | start no earlier than 2002-05-22 | Farley | 40h |
| 141 | 1.6.5.2 | Tailcone foam machining | 5d | 2002-05-29 | 2002-06-04 | 140 | 2002-05-29 | 2002-06-04 | 5d | 112d |  |  | Farley | 40h |
| 142 | 1.6.5.3 | Modular trim / ballast systems concept | 5d | 2002-05-22 | 2002-05-28 |  | 2002-05-22 | 2002-05-28 | 5d | 117d |  | start no earlier than 2002-05-22 | Rob | 40h |
| 143 | 1.6.6 | **Fairing Build** | 13d | 2002-06-10 | 2002-06-26 | 136, 139 | 2002-06-10 | 2002-06-26 | 13d | 104d |  |  | Drew | 296h |
| 144 | 1.6.6.1 | Noes section (2 plus 1 spare) | 8d | 2002-06-10 | 2002-06-19 |  | 2002-06-10 | 2002-06-19 | 8d | 109d |  | start no earlier than 2002-06-10 | ME TECH | 64h |
| 145 | 1.6.6.2 | Midboady (2 plus 1 spare) | 8d | 2002-06-13 | 2002-06-24 |  | 2002-06-13 | 2002-06-24 | 8d | 106d |  | start no earlier than 2002-06-13 | ME TECH | 64h |
| 146 | 1.6.6.3 | Tail section (2 plus 1 spare) | 8d | 2002-06-17 | 2002-06-26 |  | 2002-06-17 | 2002-06-26 | 8d | 104d |  | start no earlier than 2002-06-17 | ME TECH | 64h |

| ID | WBS | Task | Duration | Start | Finish | Predecessors | Baseline start | Baseline finish | Baseline duration | Total slack | Free slack | Constraint | Resources | Work |
| --- | --- | --- | --- | --- | --- | --- | --- | --- | --- | --- | --- | --- | --- | --- |
| 148 | 1.7 | **Software** | 107d | 2002-06-24 | 2002-11-19 |  | 2002-06-24 | 2002-11-19 | 107d | 0d |  |  | Hans | 3356h |
| 149 | 1.7.1 | Change supervisor so drivers run all the time | 3d | 2002-09-02 | 2002-09-04 |  | 2002-09-02 | 2002-09-04 | 3d | 50d | 0d | start no earlier than 2002-09-02 | Hans [50%] | 12h |
| 150 | 1.7.2 | Chang logging to convert files to MATLAB | 4d | 2002-09-05 | 2002-09-10 | 149 | 2002-09-05 | 2002-09-10 | 4d | 50d |  |  | Hans [50%] | 16h |
| 151 | 1.7.3 | **OS Upgrade** | 6d | 2002-09-12 | 2002-09-19 |  | 2002-09-12 | 2002-09-19 | 6d | 43d |  |  | Sib | 96h |
| 152 | 1.7.3.1 | QNX Upgrade to Neutrino | 3d | 2002-09-12 | 2002-09-16 |  | 2002-09-12 | 2002-09-16 | 3d | 43d | 0d | start no earlier than 2002-09-12 | Kent | 24h |
| 153 | 1.7.3.2 | Eval Linux for possible upgrade in future | 3d | 2002-09-17 | 2002-09-19 | 152 | 2002-09-17 | 2002-09-19 | 3d | 43d |  |  | Kent | 24h |
| 154 | 1.7.4 | **GUI** | 50d | 2002-07-02 | 2002-09-09 |  | 2002-07-02 | 2002-09-09 | 50d | 51d |  |  | Rich | 800h |
| 155 | 1.7.4.1 | gather requirements | 5d | 2002-07-02 | 2002-07-08 |  | 2002-07-02 | 2002-07-08 | 5d | 51d | 0d | start no earlier than 2002-07-02 | Rich | 40h |
| 156 | 1.7.4.2 | eval Bluefin GUI | 10d | 2002-07-09 | 2002-07-22 | 155 | 2002-07-09 | 2002-07-22 | 10d | 51d | 0d |  | Rich | 80h |
| 157 | 1.7.4.3 | develop GUI plan | 5d | 2002-07-23 | 2002-07-29 | 156 | 2002-07-23 | 2002-07-29 | 5d | 51d | 0d |  | Rich | 40h |
| 158 | 1.7.4.4 | Detail GUI development (TBD) | 30d | 2002-07-30 | 2002-09-09 | 157 | 2002-07-30 | 2002-09-09 | 30d | 51d |  |  | Rich | 240h |
| 159 | 1.7.5 | Configuration management on vehicle (config files) | 15d | 2002-08-16 | 2002-09-05 |  | 2002-08-16 | 2002-09-05 | 15d | 53d |  | start no earlier than 2002-08-16 | Rich | 120h |
| 160 | 1.7.6 | **Controls** | 45d | 2002-06-24 | 2002-08-23 |  | 2002-06-24 | 2002-08-23 | 45d | 62d |  |  | Rob | 720h |
| 161 | 1.7.6.1 | depth control improvement (long configs) | 15d | 2002-06-24 | 2002-07-12 |  | 2002-06-24 | 2002-07-12 | 15d | 62d | 0d | start no earlier than 2002-06-22 | Rob | 120h |
| 162 | 1.7.6.2 | sway / yaw control coupling (heave/ pitch too) | 10d | 2002-07-15 | 2002-07-26 | 161 | 2002-07-15 | 2002-07-26 | 10d | 62d | 0d |  | Rob | 80h |
| 163 | 1.7.6.3 | slow speed dynamics for control | 20d | 2002-07-29 | 2002-08-23 | 162 | 2002-07-29 | 2002-08-23 | 20d | 62d |  |  | Rob | 160h |
| 164 | 1.7.7 | **Navigation Software** | 42d | 2002-09-23 | 2002-11-19 |  | 2002-09-23 | 2002-11-19 | 42d | 0d |  |  | Hans | 684h |
| 165 | 1.7.7.1 | Document current NAV sys | 4d | 2002-09-23 | 2002-09-26 |  | 2002-09-23 | 2002-09-26 | 4d | 0d |  | start no earlier than 2002-09-23 | Hans [50%] | 16h |
| 166 | 1.7.7.2 | Streamline current nav architecture | 8d | 2002-09-27 | 2002-10-08 | 165 | 2002-09-27 | 2002-10-08 | 8d | 0d |  |  | Hans [50%] | 32h |
| 167 | 1.7.7.3 | Single beacon homing | 15d | 2002-10-09 | 2002-10-29 | 166 | 2002-10-09 | 2002-10-29 | 15d | 0d |  |  | Hans [50%] | 60h |
| 168 | 1.7.7.4 | Single beacon LBL | 15d | 2002-10-30 | 2002-11-19 | 167 | 2002-10-30 | 2002-11-19 | 15d | 0d |  |  | Hans | 120h |
| 169 | 1.7.7.5 | DVL driver enhancements for PD5 | 15d | 2002-10-09 | 2002-10-29 | 166 | 2002-10-09 | 2002-10-29 | 15d | 15d |  |  | Rob | 120h |
| 170 | 1.7.8 | **Intra-vehicle Comms** | 4d | 2002-10-01 | 2002-10-04 |  | 2002-10-01 | 2002-10-04 | 4d | 32d |  |  | Sib | 52h |
| 171 | 1.7.8.1 | set up socket code (for reconnects) | 3d | 2002-10-01 | 2002-10-03 |  | 2002-10-01 | 2002-10-03 | 3d | 32d | 0d | start no earlier than 2002-10-01 | Hans [50%] | 12h |
| 172 | 1.7.8.2 | briding over wireless | 1d | 2002-10-04 | 2002-10-04 | 171 | 2002-10-04 | 2002-10-04 | 1d | 32d |  |  | Sib | 8h |

| ID | WBS | Task | Duration | Start | Finish | Predecessors | Baseline start | Baseline finish | Baseline duration | Total slack | Free slack | Constraint | Resources | Work |
| --- | --- | --- | --- | --- | --- | --- | --- | --- | --- | --- | --- | --- | --- | --- |
| 174 | 1.8 | **Vehicle Integration and Test** | 40d | 2002-06-10 | 2002-08-02 |  | 2002-06-10 | 2002-08-02 | 40d | 76d | 0d |  | Hans | 624h |
| 175 | 1.8.1 | Tailcone Assembly | 5d | 2002-06-10 | 2002-06-14 |  | 2002-06-10 | 2002-06-14 | 5d | 86d | 0d | start no earlier than 2002-06-08 | Hans [50%] | 20h |
| 176 | 1.8.2 | Tailcone Test | 4d | 2002-06-17 | 2002-06-20 | 175 | 2002-06-17 | 2002-06-20 | 4d | 86d | 10d |  | Sib [50%] | 16h |
| 177 | 1.8.3 | Battery Midbody Integration | 5d | 2002-06-17 | 2002-06-21 |  | 2002-06-17 | 2002-06-21 | 5d | 81d | 0d | start no earlier than 2002-06-17 | Hans [50%] | 20h |
| 178 | 1.8.4 | Battery Midbody Test | 4d | 2002-06-24 | 2002-06-27 | 177 | 2002-06-24 | 2002-06-27 | 4d | 81d | 5d |  | Sib [50%] | 16h |
| 179 | 1.8.5 | ALTEX Nose Payload Assembly/Upgrade | 5d | 2002-06-17 | 2002-06-21 |  | 2002-06-17 | 2002-06-21 | 5d | 76d | 0d | start no earlier than 2002-06-17 | Drew | 40h |
| 180 | 1.8.6 | Science Payload Assembly | 6d | 2002-06-24 | 2002-07-01 | 179 | 2002-06-24 | 2002-07-01 | 6d | 76d | 0d | start no earlier than 2002-06-07 |  |  |
| 181 | 1.8.7 | Payload Test | 3d | 2002-07-02 | 2002-07-04 | 180 | 2002-07-02 | 2002-07-04 | 3d | 76d | 0d |  | Drew | 24h |
| 182 | 1.8.8 | Integrated Vehcile Deck Assembly | 2d | 2002-07-05 | 2002-07-08 | 176, 178, 181 | 2002-07-05 | 2002-07-08 | 2d | 76d | 0d |  | Drew | 16h |
| 183 | 1.8.9 | Vehicle Ballasting | 1d | 2002-07-09 | 2002-07-09 | 182 | 2002-07-09 | 2002-07-09 | 1d | 76d | 0d |  | Drew | 8h |
| 184 | 1.8.10 | Integrated Vehicle Deck Test | 3d | 2002-07-10 | 2002-07-12 | 183 | 2002-07-10 | 2002-07-12 | 3d | 76d | 0d |  | Drew | 24h |
| 185 | 1.8.11 | Integrated Vehicle Tank Test | 5d | 2002-07-15 | 2002-07-19 | 184 | 2002-07-15 | 2002-07-19 | 5d | 76d | 0d |  | Drew | 40h |
| 186 | 1.8.12 | Integrated Vehicle Sea Trials | 10d | 2002-07-22 | 2002-08-02 | 185 | 2002-07-22 | 2002-08-02 | 10d | 76d |  |  | Drew | 80h |
| 188 | 1.9 | **CTD Science Payload Core** | 33d? | 2002-06-20 | 2002-08-05 |  | 2002-06-20 | 2002-08-05 | 33d? | 76d |  |  | Drew | 504h |
| 189 | 1.9.1 | Repair/Replace nose fairing | 3d | 2002-06-20 | 2002-06-24 |  | 2002-06-20 | 2002-06-24 | 3d | 100d | 0d | start no earlier than 2002-06-20 | ME TECH | 24h |
| 190 | 1.9.2 | recable Dcon to comms and pwr bus | 8d | 2002-06-21 | 2002-07-02 |  | 2002-06-21 | 2002-07-02 | 8d | 96d | 0d | start no earlier than 2002-06-21 | EE TECH | 64h |
| 191 | 1.9.3 | Design HS2 Mount | 2d | 2002-06-25 | 2002-06-26 | 189 | 2002-06-25 | 2002-06-26 | 2d | 100d | 0d |  | ME TECH | 16h |
| 192 | 1.9.4 | Build HS2 Mount | 2d | 2002-06-27 | 2002-06-28 | 191 | 2002-06-27 | 2002-06-28 | 2d | 100d | 0d |  | ME TECH | 16h |
| 193 | 1.9.5 | Assembly HS2 Mount | 2d | 2002-07-01 | 2002-07-02 | 192 | 2002-07-01 | 2002-07-02 | 2d | 100d |  |  | ME TECH | 16h |
| 194 | 1.9.6 | Write test driver HS2 | 5d | 2002-06-27 | 2002-07-03 |  | 2002-06-27 | 2002-07-03 | 5d | 99d |  | start no earlier than 2002-06-27 | Rich | 40h |
| 195 | 1.9.7 | Eval Foam buoyancy cooridnate 1500 M version | 5d | 2002-06-28 | 2002-07-04 |  | 2002-06-28 | 2002-07-04 | 5d | 98d |  | start no earlier than 2002-06-28 | Farley | 40h |
| 196 | 1.9.8 | repair flow sensor #2 | 3d | 2002-07-03 | 2002-07-05 | 190 | 2002-07-03 | 2002-07-05 | 3d | 96d | 20d |  | EE TECH | 24h |
| 197 | 1.9.9 | test integrated CTD Payload | 1d? | 2002-08-05 | 2002-08-05 | 196, 174 | 2002-08-05 | 2002-08-05 | 1d? | 76d |  |  |  |  |
| 199 | 1.10 | **CTD Extension for Ryan/Haddock** | 21d | 2002-06-03 | 2002-07-01 |  | 2002-06-03 | 2002-07-01 | 21d | 101d |  |  | Drew | 488h |
| 200 | 1.10.1 | Design LISST pump assy | 4d | 2002-06-03 | 2002-06-06 |  | 2002-06-03 | 2002-06-06 | 4d | 101d | 0d | start no earlier than 2002-06-03 | Drew [50%] | 16h |
| 201 | 1.10.2 | Fab LISST pump assy | 5d | 2002-06-07 | 2002-06-13 | 200 | 2002-06-07 | 2002-06-13 | 5d | 104d | 0d |  | Shop | 40h |
| 202 | 1.10.3 | Assy LISST pump into vehicle | 2d | 2002-06-14 | 2002-06-17 | 201 | 2002-06-14 | 2002-06-17 | 2d | 104d | 3d |  | ME TECH | 16h |
| 203 | 1.10.4 | Design LISST mount | 5d | 2002-06-07 | 2002-06-13 | 200 | 2002-06-07 | 2002-06-13 | 5d | 101d | 0d |  | Farley | 40h |
| 204 | 1.10.5 | Fab LISST Mount | 5d | 2002-06-14 | 2002-06-20 | 203 | 2002-06-14 | 2002-06-20 | 5d | 101d | 0d |  | Shop | 40h |
| 205 | 1.10.6 | Assy LISST mount | 2d | 2002-06-21 | 2002-06-24 | 202, 204 | 2002-06-21 | 2002-06-24 | 2d | 101d | 0d |  | ME TECH | 16h |
| 206 | 1.10.7 | Cable LISST to Dcon | 1d | 2002-06-25 | 2002-06-25 | 205 | 2002-06-25 | 2002-06-25 | 1d | 105d |  |  | EE TECH | 8h |
| 207 | 1.10.8 | Write Test Driver for LISST | 5d | 2002-06-25 | 2002-07-01 | 205 | 2002-06-25 | 2002-07-01 | 5d | 101d |  |  | Rich | 40h |
| 208 | 1.10.9 | Design Bathypho mount | 4d | 2002-06-05 | 2002-06-10 |  | 2002-06-05 | 2002-06-10 | 4d | 105d | 0d | start no earlier than 2002-06-05 | Drew [50%] | 16h |
| 209 | 1.10.10 | Fab Bathypho mount | 5d | 2002-06-11 | 2002-06-17 | 208 | 2002-06-11 | 2002-06-17 | 5d | 105d | 0d |  | ME TECH | 40h |
| 210 | 1.10.11 | Assy Bathypho mount | 2d | 2002-06-18 | 2002-06-19 | 209 | 2002-06-18 | 2002-06-19 | 2d | 105d | 0d |  | ME TECH | 16h |
| 211 | 1.10.12 | Cable Bathypho to Dcon | 1d | 2002-06-20 | 2002-06-20 | 210 | 2002-06-20 | 2002-06-20 | 1d | 105d | 0d |  | EE TECH | 8h |
| 212 | 1.10.13 | Retest driver for Bathypho (already written) | 3d | 2002-06-21 | 2002-06-25 | 211 | 2002-06-21 | 2002-06-25 | 3d | 105d |  |  | Rich | 24h |
| 214 | 1.11 | Ryan / Haddock Cruise Prep | 14d | 2002-07-29 | 2002-08-15 |  | 2002-07-29 | 2002-08-15 | 14d | 68d |  | start no earlier than 2002-07-27 | Hans | 112h |
