# Dorado2002revE

Schedule from MS Project, 2002-03-15 to 2002-11-19, status date 2002-06-03, A marks actual dates.
KEE Systems

## Calendars

- Standard: Mon-Fri 08:00-12:00, 13:00-17:00; Sat-Sun off.

## Resources

| Resource |
| --- |
| Hans |
| Drew |
| Sib |
| Farley |
| ME |
| Rob |
| Rich |
| Craig |
| Kent |
| ME TECH |
| EE TECH |
| Shop |
| Kiwi |
| Robert F |
| RobF |
| Cancelled Task |
| On Hold |
| Seacon |
| Eric |

## Schedule

| ID | WBS | Task | Duration | Start | Finish | Predecessors | Complete | Remaining | Baseline start | Baseline finish | Baseline duration | Total slack | Free slack | Constraint | Resources | Work | Actual work |
| --- | --- | --- | --- | --- | --- | --- | --- | --- | --- | --- | --- | --- | --- | --- | --- | --- | --- |
| 1 | 1 | **Dorado Program** | 178d? | 2002-03-15 A | 2002-11-19 |  | 15% | 151.97d? | 2002-03-15 | 2002-11-19 | 178d? | 0d |  |  |  | 17731.6h | 3279.88h |
| 3 | 1.1 | **Propulsion** | 88d | 2002-05-20 A | 2002-09-18 |  | 10% | 79.13d | 2002-05-02 | 2002-09-17 | 99d | 44d |  |  |  | 766h | 94h |
| 4 | 1.1.1 | **Articulated Tail** | 83d | 2002-05-20 A | 2002-09-11 |  | 38% | 51.18d | 2002-05-02 | 2002-09-11 | 95d | 44d | 0d |  |  | 212h | 92h |
| 5 | 1.1.1.1 | Design & Build New Electronics Housing | 23d | 2002-05-20 A | 2002-06-19 |  | 50% | 11.5d | 2002-05-02 | 2002-05-15 | 10d | 104d |  | start no earlier than 2002-05-02 | Farley | 184h | 92h |
| 6 | 1.1.1.2 | New Linear Actuator Scheme | 7d | 2002-09-03 | 2002-09-11 |  |  |  | 2002-09-03 | 2002-09-11 | 7d | 45d |  | start no earlier than 2002-09-03 | Hans [50%] | 28h |  |
| 7 | 1.1.2 | **Drive Electronics** | 41d | 2002-05-27 A | 2002-07-22 |  |  | 41d | 2002-05-06 | 2002-06-06 | 24d | 81d | 0d |  |  | 136h |  |
| 8 | 1.1.2.1 | Integrate New Electroincs | 24d | 2002-06-19 A | 2002-07-22 |  |  | 24d | 2002-05-06 | 2002-06-06 | 24d | 81d |  | start no earlier than 2002-05-05 | Sib [50%] | 96h |  |
| 9 | 1.1.2.2 | Cabling | 5d | 2002-05-27 | 2002-05-31 |  |  |  | 2002-05-27 | 2002-05-31 | 5d | 117d |  | start no earlier than 2002-05-27 | EE TECH | 40h |  |
| 10 | 1.1.3 | Integrate New Tail Into fairing | 5d | 2002-07-23 | 2002-07-29 | 7 |  |  | 2002-06-07 | 2002-06-13 | 5d | 81d |  |  | Farley | 40h |  |
| 11 | 1.1.4 | Tailcone - Bench Stand Design and Fab | 3d | 2002-05-27 | 2002-05-29 |  |  |  | 2002-05-27 | 2002-05-29 | 3d | 124d |  | start no earlier than 2002-05-27 | ME TECH | 24h |  |
| 12 | 1.1.5 | Buoyancy Check / Test | 1d | 2002-06-14 A | 2002-06-14 A | 10 | 100% |  | 2002-06-14 | 2002-06-14 | 1d |  |  |  | Drew [25%] | 2h | 2h |
| 13 | 1.1.6 | Test Plan | 5d | 2002-06-14 | 2002-06-20 |  |  |  | 2002-06-14 | 2002-06-20 | 5d | 108d |  | start no earlier than 2002-06-14 | Rob | 40h |  |
| 14 | 1.1.7 | Replace foam with 4500 M | 20d | 2002-06-17 | 2002-07-12 |  |  |  |  |  |  | 92d |  | start no earlier than 2002-06-17 | Drew [15%] | 24h |  |
| 15 | 1.1.8 | Compensator Design/Purchase | 20d | 2002-06-10 | 2002-07-05 |  |  |  |  |  |  | 97d |  | start no earlier than 2002-06-10 | Robert F | 160h |  |
| 16 | 1.1.9 | **Tailcone Documetation** | 5d | 2002-09-12 | 2002-09-18 | 7, 4 |  |  | 2002-09-12 | 2002-09-17 | 4d | 44d |  |  |  | 128h |  |
| 17 | 1.1.9.1 | Mechanical | 5d | 2002-09-12 | 2002-09-18 |  |  |  | 2002-09-12 | 2002-09-16 | 3d | 44d |  |  | Farley; RobF | 80h |  |
| 18 | 1.1.9.2 | Electrical | 2d | 2002-09-12 | 2002-09-13 |  |  |  | 2002-09-12 | 2002-09-13 | 2d | 47d |  | start no earlier than 2002-09-02 | Sib | 16h |  |
| 19 | 1.1.9.3 | Software | 4d | 2002-09-12 | 2002-09-17 |  |  |  | 2002-09-12 | 2002-09-17 | 4d | 45d |  | start no earlier than 2002-09-04 | Sib | 32h |  |
| 21 | 1.2 | **Power** | 95d? | 2002-04-15 A | 2002-08-23 |  | 10% | 85.97d? | 2002-04-15 | 2002-06-24 | 51d? | 62d |  |  | Hans | 3101.2h | 322.85h |
| 22 | 1.2.1 | **Battery Chemistry** | 91d? | 2002-04-15 A | 2002-08-19 |  | 9% | 82.41d? | 2002-04-15 | 2002-05-23 | 29d | 66d |  |  | Hans | 876h | 96.86h |
| 23 | 1.2.1.1 | Check life on current Ag-Zn batteries | 4d | 2002-04-15 A | 2002-04-18 |  | 66% | 1.36d | 2002-04-15 | 2002-04-18 | 4d | 153d |  | start no earlier than 2002-04-13 | Hans [50%] | 16h | 10.56h |
| 24 | 1.2.1.2 | Trade study to review Batt Chems | 3d | 2002-04-18 A | 2002-04-22 |  | 80% | 0.6d | 2002-04-18 | 2002-04-22 | 3d | 151d |  | start no earlier than 2002-04-18 | Hans [50%] | 12h | 9.6h |
| 25 | 1.2.1.3 | Thermal Analysis of Battery Pack | 5d | 2002-04-17 | 2002-04-23 |  |  |  | 2002-04-17 | 2002-04-23 | 5d | 150d |  | start no earlier than 2002-04-17 | Cancelled Task | 40h |  |
| 26 | 1.2.1.4 | Design Review of Batt Chems | 1d | 2002-06-03 A | 2002-06-03 A | 23, 24, 25 | 100% |  | 2002-04-24 | 2002-04-24 | 1d |  |  |  | Hans | 8h | 8h |
| 27 | 1.2.1.5 | Purchase Batteries | 4d | 2002-06-04 | 2002-06-07 | 26 |  |  | 2002-04-25 | 2002-04-25 | 1d | 66d | 4d |  | Hans [50%] | 16h |  |
| 28 | 1.2.1.6 | Battery delivery | 40d? | 2002-06-14 | 2002-08-08 | 27 |  |  |  |  |  | 62d | 0d | start no earlier than 2002-06-14 |  |  |  |
| 29 | 1.2.1.7 | Assemble Batteries | 4d | 2002-08-09 | 2002-08-14 | 28 |  |  | 2002-04-26 | 2002-05-02 | 5d | 62d | 0d |  | EE TECH | 32h |  |
| 30 | 1.2.1.8 | Test Batteries | 3d | 2002-08-15 | 2002-08-19 | 29 |  |  | 2002-05-03 | 2002-05-23 | 15d | 62d | 0d |  | EE TECH | 24h |  |

| ID | WBS | Task | Duration | Start | Finish | Predecessors | Complete | Remaining | Baseline start | Baseline finish | Baseline duration | Total slack | Free slack | Constraint | Resources | Work | Actual work |
| --- | --- | --- | --- | --- | --- | --- | --- | --- | --- | --- | --- | --- | --- | --- | --- | --- | --- |
| 31 | 1.2.2 | **Battery Housing** | 58d | 2002-04-25 A | 2002-07-15 | 26 | 12% | 51.18d | 2002-04-25 | 2002-06-11 | 34d | 91d |  |  | Hans | 736h | 86.59h |
| 32 | 1.2.2.1 | Design | 10d | 2002-06-04 | 2002-06-17 |  |  |  | 2002-05-01 | 2002-05-14 | 10d | 91d | 0d | start no earlier than 2002-05-01 | On Hold | 80h |  |
| 33 | 1.2.2.2 | Build | 15d | 2002-06-18 | 2002-07-08 | 32 |  |  | 2002-05-15 | 2002-06-04 | 15d | 91d | 0d |  | On Hold | 120h |  |
| 34 | 1.2.2.3 | Test | 5d | 2002-07-09 | 2002-07-15 | 33 |  |  | 2002-06-05 | 2002-06-11 | 5d | 91d |  |  | On Hold | 40h |  |
| 35 | 1.2.2.4 | Spec Interconnects | 4d | 2002-04-25 A | 2002-04-30 A |  | 100% |  | 2002-04-25 | 2002-04-30 | 4d |  |  | start no earlier than 2002-03-28 | Sib | 32h | 32h |
| 36 | 1.2.3 | **Battery Electronics** | 59d? | 2002-06-04 A | 2002-08-23 | 26, 35 | 10% | 53.1d? | 2002-05-01 | 2002-06-10 | 29d? | 62d |  |  | Sib | 650h | 67.2h |
| 37 | 1.2.3.1 | Concept Design | 5d | 2002-06-04 A | 2002-06-10 |  | 50% | 2.5d | 2002-05-01 | 2002-05-07 | 5d | 100d | 0d | start no earlier than 2002-04-22 | Sib | 40h | 20h |
| 38 | 1.2.3.2 | Design Review | 2d | 2002-06-11 | 2002-06-12 | 37 |  |  | 2002-05-08 | 2002-05-09 | 2d | 100d | 0d |  | Sib | 16h |  |
| 39 | 1.2.3.3 | Final Design | 11d | 2002-06-13 | 2002-06-27 | 38 |  |  | 2002-05-10 | 2002-05-24 | 11d | 100d | 0d | start no earlier than 2002-05-01 | Sib [75%] | 66h |  |
| 40 | 1.2.3.4 | Build | 1d | 2002-06-28 | 2002-06-28 | 39 |  |  | 2002-05-27 | 2002-05-27 | 1d | 100d | 0d |  | EE TECH | 8h |  |
| 41 | 1.2.3.5 | Assemble | 1d | 2002-07-01 | 2002-07-01 | 40 |  |  | 2002-05-28 | 2002-05-28 | 1d | 100d | 0d |  | EE TECH | 8h |  |
| 42 | 1.2.3.6 | Test | 1d | 2002-07-02 | 2002-07-02 | 41 |  |  | 2002-05-29 | 2002-05-29 | 1d | 100d |  |  | EE TECH | 8h |  |
| 43 | 1.2.3.7 | Spec Misc Electronics (Contingency) | 4d? | 2002-08-20 | 2002-08-23 | 30 |  |  | 2002-06-10 | 2002-06-10 | 1d? | 62d |  | start no earlier than 2002-06-10 | Sib | 32h |  |
| 44 | 1.2.4 | **Battery Charging** | 4d | 2002-06-21 | 2002-06-26 | 26 |  |  | 2002-06-11 | 2002-06-12 | 2d | 104d |  |  | Hans | 47.2h |  |
| 45 | 1.2.4.1 | Spec Charging Analysis | 2d | 2002-06-21 | 2002-06-24 |  |  |  | 2002-06-11 | 2002-06-12 | 2d | 106d |  | start no earlier than 2002-06-21 | Hans [20%] | 3.2h |  |
| 46 | 1.2.4.2 | Order Charging Equip as Required | 3d | 2002-06-24 | 2002-06-26 |  |  |  | 2002-06-11 | 2002-06-11 | 1d | 104d |  | start no earlier than 2002-06-22 | Hans [50%] | 12h |  |
| 47 | 1.2.5 | AUV Power Systems Meeting | 4d | 2002-06-19 | 2002-06-24 |  |  |  | 2002-06-19 | 2002-06-24 | 4d | 106d |  | start no earlier than 2002-06-19 | Hans | 32h |  |
| 49 | 1.3 | **Cabling and Connectors** | 64d | 2002-04-25 A | 2002-07-23 | 26 | 44% | 35.57d | 2002-04-25 | 2002-06-21 | 42d | 85d |  |  |  | 459.2h | 173.6h |
| 50 | 1.3.1 | Spec Main Power / Comms Cable&Connectors/Penetrators | 13d | 2002-04-25 A | 2002-06-12 A |  | 100% |  | 2002-04-25 | 2002-05-13 | 13d |  |  |  | Hans [50%] | 52h | 52h |
| 51 | 1.3.2 | Spec Charging Connector | 4d | 2002-06-12 A | 2002-06-18 | 50 | 50% | 2d | 2002-05-14 | 2002-05-17 | 4d | 110.5d |  |  | Hans [25%] | 8h | 4h |
| 52 | 1.3.3 | Spec Tailcone Comms Cable&Connector/Penetrator | 4.4d | 2002-04-25 A | 2002-06-05 A |  | 100% |  | 2002-04-25 | 2002-04-29 | 3d |  |  | start no earlier than 2002-03-18 | Sib | 35.2h | 35.2h |
| 53 | 1.3.4 | Spec Science Instrument Connector | 2d | 2002-04-25 A | 2002-04-26 A |  | 100% |  | 2002-04-25 | 2002-04-26 | 2d |  |  | start no earlier than 2002-04-24 | Drew [25%] | 4h | 4h |
| 54 | 1.3.5 | Spec DVL and parosci Connectors / Penetrator | 1d | 2002-04-29 A | 2002-04-29 A | 53 | 100% |  | 2002-04-29 | 2002-04-29 | 1d |  |  |  | Drew [25%] | 2h | 2h |
| 55 | 1.3.6 | Spec RF/Acoustic/Emer location Connect & Penetrators | 1d | 2002-04-30 A | 2002-04-30 A | 54 | 100% |  | 2002-04-30 | 2002-04-30 | 1d |  |  |  | Drew [50%] | 4h | 4h |
| 56 | 1.3.7 | Spec On/Off Connector/Penetrator | 1d | 2002-05-01 A | 2002-05-01 A | 55 | 100% |  | 2002-05-01 | 2002-05-01 | 1d |  |  |  | Drew [25%] | 2h | 2h |
| 57 | 1.3.8 | Test ability of 100 MB/s thrugh current ALTEX Cable | 2d | 2002-05-21 A | 2002-05-22 A |  | 100% |  | 2002-05-21 | 2002-05-22 | 2d |  |  | start no earlier than 2002-05-21 | Drew | 16h | 16h |
| 58 | 1.3.9 | Order Connectors | 5d | 2002-05-14 A | 2002-05-20 A | 50, 52, 56 | 100% |  | 2002-05-14 | 2002-05-15 | 2d |  |  |  | Drew | 40h | 40h |

| ID | WBS | Task | Duration | Start | Finish | Predecessors | Complete | Remaining | Baseline start | Baseline finish | Baseline duration | Total slack | Free slack | Constraint | Resources | Work | Actual work |
| --- | --- | --- | --- | --- | --- | --- | --- | --- | --- | --- | --- | --- | --- | --- | --- | --- | --- |
| 59 | 1.3.10 | **Tail to MVC** | 4d | 2002-06-04 A | 2002-06-07 |  | 30% | 2.8d | 2002-05-09 | 2002-05-09 | 1d | 107d |  |  | Drew | 48h | 14.4h |
| 60 | 1.3.10.1 | Section Interconnect | 4d | 2002-06-04 A | 2002-06-07 |  | 30% | 2.8d | 2002-05-09 | 2002-05-09 | 1d | 107d | 3d | start no earlier than 2002-05-09 | Drew [50%] | 16h | 4.8h |
| 61 | 1.3.11 | Documetation package on Connectors and Cabling | 10d | 2002-06-13 | 2002-06-26 | 58, 60 |  |  | 2002-06-10 | 2002-06-21 | 10d | 104d |  | start no earlier than 2002-06-13 | Drew [50%] | 40h |  |
| 62 | 1.3.12 | Cable Assy @ Seacon | 26d | 2002-06-18 | 2002-07-23 |  |  |  |  |  |  | 85d |  | start no earlier than 2002-06-18 | Seacon | 208h |  |
| 64 | 1.4 | **Main Vehicle Computer** | 146d | 2002-03-15 A | 2002-10-04 |  | 44% | 81.24d | 2002-03-15 | 2002-09-19 | 135d | 32d |  |  | Sib | 4542h | 2064.01h |
| 65 | 1.4.1 | **Electronics** | 136d | 2002-03-15 A | 2002-09-20 |  | 60% | 54.73d | 2002-03-15 | 2002-06-05 | 59d | 42d |  |  | Sib | 2318h | 1379.66h |
| 66 | 1.4.1.1 | Spec PC 104 Stack | 2d | 2002-03-15 A | 2002-03-18 A |  | 100% |  | 2002-03-15 | 2002-03-18 | 2d |  |  |  | Sib | 16h | 16h |
| 67 | 1.4.1.2 | Order PC 104 Stack | 2d | 2002-03-19 A | 2002-05-07 A | 66 | 100% |  | 2002-03-19 | 2002-05-07 | 2d |  |  |  | Sib | 16h | 16h |
| 68 | 1.4.1.3 | Assemble PC 104 Stack | 2d | 2002-05-07 A | 2002-05-09 A | 67 | 100% |  | 2002-05-07 | 2002-05-09 | 2d |  |  |  | EE TECH | 16h | 16h |
| 69 | 1.4.1.4 | Develop latency test/budget for MVC | 10d | 2002-05-27 A | 2002-06-07 |  | 50% | 5d | 2002-05-13 | 2002-05-16 | 4d | 117d |  | start no earlier than 2002-05-11 | Sib [50%] | 40h | 20h |
| 70 | 1.4.1.5 | **Power Board** | 37.5d | 2002-04-28 A | 2002-06-19 | 26 | 87% | 4.89d | 2002-04-28 | 2002-05-29 | 23d | 99.5d | 67.5d |  | Sib | 398h | 340.08h |
| 71 | 1.4.1.5.1 | Specify | 4d | 2002-04-28 A | 2002-05-02 A |  | 100% |  | 2002-04-28 | 2002-05-02 | 4d |  |  | start no earlier than 2002-05-06 | Sib [50%] | 16h | 16h |
| 72 | 1.4.1.5.2 | Design | 15d | 2002-05-03 A | 2002-06-13 A | 71 | 100% |  | 2002-05-03 | 2002-05-23 | 15d |  |  |  | Sib [75%] | 90h | 90h |
| 73 | 1.4.1.5.3 | Order | 1d | 2002-06-13 A | 2002-06-14 A | 72 | 100% |  | 2002-05-24 | 2002-05-24 | 1d |  |  |  | Sib | 8h | 8h |
| 74 | 1.4.1.5.4 | Build | 2d | 2002-06-14 | 2002-06-18 | 73 |  |  | 2002-05-27 | 2002-05-28 | 2d | 99.5d | 0d |  | EE TECH | 16h |  |
| 75 | 1.4.1.5.5 | Test | 1d | 2002-06-18 | 2002-06-19 | 74 |  |  | 2002-05-29 | 2002-05-29 | 1d | 99.5d |  |  | EE TECH | 8h |  |
| 76 | 1.4.1.6 | **RF Modem** | 44d | 2002-03-15 A | 2002-05-15 |  | 71% | 12.57d | 2002-03-15 | 2002-05-15 | 44d | 134d |  |  | Drew | 376h | 271.43h |
| 77 | 1.4.1.6.1 | Evaluate Data-link vs Freewave | 5d | 2002-03-15 A | 2002-03-21 A |  | 100% |  | 2002-03-15 | 2002-03-21 | 5d |  |  |  | Eric [50%] | 20h | 20h |
| 78 | 1.4.1.6.2 | Purchase | 2d | 2002-05-14 | 2002-05-15 |  |  |  | 2002-05-14 | 2002-05-15 | 2d | 134d |  | start no earlier than 2002-05-14 | Drew [25%] | 4h |  |
| 79 | 1.4.1.7 | **Acoustic Modem** | 5d | 2002-09-16 A | 2002-09-20 |  |  | 5d | 2002-05-17 | 2002-05-20 | 2d | 32d | 0d |  | Hans | 60h |  |
| 80 | 1.4.1.7.1 | Evaluate | 2d | 2002-09-16 A | 2002-09-17 |  |  | 2d | 2002-05-17 | 2002-05-17 | 1d | 32d | 0d | start no earlier than 2002-05-17 | Hans [50%] | 8h |  |
| 81 | 1.4.1.7.2 | Purchase | 3d | 2002-09-18 | 2002-09-20 | 80 |  |  | 2002-05-20 | 2002-05-20 | 1d | 32d |  |  | Hans [50%] | 12h |  |
| 82 | 1.4.1.8 | **GPS** | 15d | 2002-06-10 A | 2002-06-28 |  |  | 15d | 2002-05-16 | 2002-06-05 | 15d | 92d | 60d |  | Eric | 234h |  |
| 83 | 1.4.1.8.1 | Evaluate GPS Position Fix Problem | 10d | 2002-06-10 A | 2002-06-21 |  |  | 10d | 2002-05-16 | 2002-05-29 | 10d | 92d | 0d | start no earlier than 2002-05-16 | Eric | 80h |  |
| 84 | 1.4.1.8.2 | Evaluate GPS Board & Antennae | 4d | 2002-06-24 | 2002-06-27 | 83 |  |  | 2002-05-30 | 2002-06-04 | 4d | 92d | 0d |  | Eric | 32h |  |
| 85 | 1.4.1.8.3 | Purchase GPS Board & Antennae | 1d | 2002-06-28 | 2002-06-28 | 84 |  |  | 2002-06-05 | 2002-06-05 | 1d | 92d |  |  | Eric [25%] | 2h |  |
| 86 | 1.4.1.9 | Eval and Purchase 10/100 Hub | 4d | 2002-03-20 A | 2002-03-25 A |  | 100% |  | 2002-03-20 | 2002-03-25 | 4d |  |  | start no earlier than 2002-03-20 | Sib [25%] | 8h | 8h |
| 87 | 1.4.1.10 | Eval & Purchase AHRS | 1d | 2002-03-15 A | 2002-03-15 A |  | 100% |  | 2002-03-15 | 2002-03-15 | 1d |  |  |  | Drew [25%] | 2h | 2h |
| 88 | 1.4.1.11 | Eval and Purchase LBL Board Set | 4d | 2002-03-15 A | 2002-03-20 A |  | 100% |  | 2002-03-15 | 2002-03-20 | 4d |  |  |  | Hans [25%] | 8h | 8h |
| 89 | 1.4.1.12 | Spec and Purcahse DVL | 7d | 2002-05-14 A | 2002-08-09 |  | 57% | 3d | 2002-05-14 | 2002-05-20 | 5d | 72d |  |  | Rob | 56h | 32h |

| ID | WBS | Task | Duration | Start | Finish | Predecessors | Complete | Remaining | Baseline start | Baseline finish | Baseline duration | Total slack | Free slack | Constraint | Resources | Work | Actual work |
| --- | --- | --- | --- | --- | --- | --- | --- | --- | --- | --- | --- | --- | --- | --- | --- | --- | --- |
| 90 | 1.4.2 | **MVC Housing** | 83d | 2002-03-15 A | 2002-07-09 |  | 21% | 65.21d | 2002-03-15 | 2002-06-04 | 58d | 85d |  |  | Drew | 864h | 166.28h |
| 91 | 1.4.2.1 | Spec Interconnects | 6d | 2002-03-15 A | 2002-03-22 A |  | 100% |  | 2002-03-15 | 2002-03-22 | 6d |  |  |  | Drew [50%] | 24h | 24h |
| 92 | 1.4.2.2 | Design | 5d | 2002-06-10 | 2002-06-14 | 91 |  |  | 2002-05-06 | 2002-05-10 | 5d | 85d | 0d | start no earlier than 2002-06-09 | Farley | 40h |  |
| 93 | 1.4.2.3 | Build/Purchase | 10d | 2002-06-17 | 2002-06-28 | 92 |  |  | 2002-05-13 | 2002-05-24 | 10d | 85d | 0d |  | Shop | 80h |  |
| 94 | 1.4.2.4 | Pressure Test | 2d | 2002-07-01 | 2002-07-02 | 93 |  |  | 2002-05-27 | 2002-05-28 | 2d | 85d | 0d |  | ME TECH | 16h |  |
| 95 | 1.4.2.5 | Electronics Packagin Layout | 5d | 2002-07-03 | 2002-07-09 | 94 |  |  | 2002-05-29 | 2002-06-04 | 5d | 85d | 53d |  | Drew | 40h |  |
| 96 | 1.4.3 | **Documentation Package** | 10d | 2002-09-23 | 2002-10-04 | 95, 82, 79, 70 |  |  | 2002-09-05 | 2002-09-19 | 11d | 32d |  |  | Sib | 192h |  |
| 97 | 1.4.3.1 | Mechanical | 2d | 2002-09-23 | 2002-09-24 |  |  |  | 2002-09-05 | 2002-09-06 | 2d | 38d | 6d | start no earlier than 2002-09-05 | Farley | 16h |  |
| 98 | 1.4.3.2 | Electrical | 8d | 2002-09-23 | 2002-10-02 |  |  |  | 2002-09-05 | 2002-09-16 | 8d | 32d | 0d | start no earlier than 2002-09-05 | Sib | 64h |  |
| 99 | 1.4.3.3 | Software | 2d | 2002-09-23 | 2002-09-24 |  |  |  | 2002-09-16 | 2002-09-17 | 2d | 38d | 6d | start no earlier than 2002-09-16 | Hans | 16h |  |
| 100 | 1.4.3.4 | Integration | 2d | 2002-10-03 | 2002-10-04 | 98, 99, 97 |  |  | 2002-09-18 | 2002-09-19 | 2d | 32d |  | start no earlier than 2002-07-25 | Sib | 16h |  |
| 102 | 1.5 | **Navigation Hardware & Testing** | 53d | 2002-09-02 A | 2002-11-13 |  | 2% | 52.12d | 2002-09-02 | 2002-11-13 | 53d | 4d |  |  | Hans | 1159.2h | 11.07h |
| 103 | 1.5.1 | **Deep Water testing of USBL** | 38d | 2002-09-02 | 2002-10-23 |  |  |  | 2002-09-02 | 2002-10-23 | 38d | 4d | 0d |  | Hans | 467.2h |  |
| 104 | 1.5.1.1 | Tank testing | 18d | 2002-09-02 | 2002-09-25 |  |  |  | 2002-09-02 | 2002-09-25 | 18d | 4d | 0d | start no earlier than 2002-09-01 | Hans [30%] | 43.2h |  |
| 105 | 1.5.1.2 | At Sea Testing | 20d | 2002-09-26 | 2002-10-23 | 104 |  |  | 2002-09-26 | 2002-10-23 | 20d | 4d |  |  | Hans [75%] | 120h |  |
| 106 | 1.5.2 | **Deep Water Testing of LBL Fish Mode** | 15d | 2002-10-24 | 2002-11-13 | 103 |  |  | 2002-10-24 | 2002-11-13 | 15d | 4d |  |  | Hans | 240h |  |
| 107 | 1.5.2.1 | Tank Testing | 10d | 2002-10-24 | 2002-11-06 |  |  |  | 2002-10-24 | 2002-11-06 | 10d | 4d | 0d | start no earlier than 2002-09-09 | Hans | 80h |  |
| 108 | 1.5.2.2 | At Sea Testing | 5d | 2002-11-07 | 2002-11-13 | 107 |  |  | 2002-11-07 | 2002-11-13 | 5d | 4d |  |  | Hans | 40h |  |
| 109 | 1.5.3 | Radio Range for modems | 3d | 2002-09-06 | 2002-09-10 |  |  |  | 2002-09-06 | 2002-09-10 | 3d | 50d |  | start no earlier than 2002-09-06 | Drew [50%] | 12h |  |
| 110 | 1.5.4 | RDF Ranging | 3d | 2002-09-09 | 2002-09-11 |  |  |  | 2002-09-09 | 2002-09-11 | 3d | 49d |  | start no earlier than 2002-09-07 | Drew [50%] | 12h |  |
| 111 | 1.5.5 | Eval Zephyr RDF capability | 1d | 2002-09-12 A | 2002-09-12 A | 110 | 100% |  | 2002-09-12 | 2002-09-12 | 1d |  |  |  | Drew [50%] | 4h | 4h |
| 113 | 1.6 | **Fairings / Vehicle Mechanical Structure** | 155d | 2002-03-15 A | 2002-10-17 |  | 14% | 133.67d | 2002-03-15 | 2002-07-05 | 81d | 23d |  |  |  | 2452h | 418.44h |
| 114 | 1.6.1 | **L&R System Interface** | 101d | 2002-03-15 A | 2002-08-02 |  | 28% | 72.29d | 2002-03-15 | 2002-07-05 | 81d | 77d |  |  | Drew | 1188h | 337.64h |
| 115 | 1.6.1.1 | Prelim Concept w/ Brook ocean | 5d | 2002-03-15 A | 2002-03-21 A |  | 100% |  | 2002-03-15 | 2002-03-21 | 5d |  |  |  | Farley | 40h | 40h |
| 116 | 1.6.1.2 | Concept Design Review / Decision | 5.5d | 2002-03-22 A | 2002-05-24 A | 115 | 100% |  | 2002-03-22 | 2002-05-24 | 5.5d |  |  |  | Farley | 44h | 44h |
| 117 | 1.6.1.3 | Design L&R Interface | 10d | 2002-06-24 | 2002-07-05 |  |  |  | 2002-05-27 | 2002-06-07 | 10d | 77d | 0d | start no earlier than 2002-06-22 | Farley | 80h |  |
| 118 | 1.6.1.4 | Build Interface | 10d | 2002-07-08 | 2002-07-19 | 117 |  |  | 2002-06-10 | 2002-06-21 | 10d | 77d | 0d |  | Shop | 80h |  |
| 119 | 1.6.1.5 | Assemble Interface | 5d | 2002-07-22 | 2002-07-26 | 118 |  |  | 2002-06-24 | 2002-06-28 | 5d | 77d | 0d |  | ME TECH | 40h |  |
| 120 | 1.6.1.6 | L&R test plan | 4d | 2002-06-24 | 2002-06-27 |  |  |  | 2002-05-27 | 2002-05-30 | 4d | 98d | 21d | start no earlier than 2002-06-24 | Drew | 32h |  |
| 121 | 1.6.1.7 | Integrate and Test L&R Interface | 5d | 2002-07-29 | 2002-08-02 | 120, 119 |  |  | 2002-07-01 | 2002-07-05 | 5d | 77d |  |  | Farley | 40h |  |
| 122 | 1.6.1.8 | Evaluate Single Point lift | 3d | 2002-05-06 A | 2002-05-08 A |  | 100% |  | 2002-05-06 | 2002-05-08 | 3d |  |  | start no earlier than 2002-05-04 | Drew | 24h | 24h |

| ID | WBS | Task | Duration | Start | Finish | Predecessors | Complete | Remaining | Baseline start | Baseline finish | Baseline duration | Total slack | Free slack | Constraint | Resources | Work | Actual work |
| --- | --- | --- | --- | --- | --- | --- | --- | --- | --- | --- | --- | --- | --- | --- | --- | --- | --- |
| 123 | 1.6.2 | **Joining Ring/Systems** | 34d | 2002-09-02 | 2002-10-17 |  |  |  | 2002-05-10 | 2002-07-01 | 37d | 23d |  |  | Drew | 568h |  |
| 124 | 1.6.2.1 | Evaluate joining ring systems | 2d | 2002-09-02 | 2002-09-03 |  |  |  | 2002-05-10 | 2002-05-13 | 2d | 23d | 0d | start no earlier than 2002-09-02 | Farley | 16h |  |
| 125 | 1.6.2.2 | Review Concept | 1d | 2002-09-04 | 2002-09-04 | 124 |  |  | 2002-05-14 | 2002-05-14 | 1d | 23d | 0d |  | Farley | 8h |  |
| 126 | 1.6.2.3 | Final Design | 15d | 2002-09-05 | 2002-09-25 | 125 |  |  | 2002-05-15 | 2002-06-04 | 15d | 23d | 0d |  | Farley | 120h |  |
| 127 | 1.6.2.4 | Build | 10d | 2002-09-26 | 2002-10-09 | 126 |  |  | 2002-06-05 | 2002-06-18 | 10d | 23d | 0d |  | Shop | 80h |  |
| 128 | 1.6.2.5 | Assemble | 3d | 2002-10-10 | 2002-10-14 | 127 |  |  | 2002-06-19 | 2002-06-21 | 3d | 23d | 0d |  | ME TECH | 24h |  |
| 129 | 1.6.2.6 | Test | 3d | 2002-10-15 | 2002-10-17 | 128 |  |  | 2002-06-24 | 2002-06-26 | 3d | 23d |  |  | Drew | 24h |  |
| 130 | 1.6.2.7 | Test new joining ring system | 3d | 2002-09-17 | 2002-09-19 |  |  |  | 2002-06-27 | 2002-07-01 | 3d | 43d |  | start no earlier than 2002-09-17 | Drew | 24h |  |
| 131 | 1.6.3 | **Deck Handling Equipment** | 88d | 2002-05-20 A | 2002-09-18 |  | 28% | 63.31d | 2002-05-20 | 2002-06-07 | 15d | 44d |  |  |  | 288h | 80.8h |
| 132 | 1.6.3.1 | New Cart Design | 7d | 2002-05-20 A | 2002-07-05 |  | 50% | 3.5d | 2002-05-20 | 2002-05-24 | 5d | 97d |  | start no earlier than 2002-05-19 | ME TECH | 56h | 28h |
| 133 | 1.6.3.2 | New Lifitng Gear | 7d | 2002-05-27 A | 2002-07-05 |  | 30% | 4.9d | 2002-05-27 | 2002-05-31 | 5d | 97d |  | start no earlier than 2002-05-25 | ME TECH | 56h | 16.8h |
| 134 | 1.6.3.3 | Sphere Lift Mechanism | 10d | 2002-09-05 | 2002-09-18 |  |  |  | 2002-05-21 | 2002-06-03 | 10d | 44d |  | start no earlier than 2002-09-05 | Farley | 80h |  |
| 135 | 1.6.3.4 | Eval Single Pt. Lift | 2d | 2002-05-23 A | 2002-05-24 A |  | 100% |  | 2002-05-23 | 2002-05-24 | 2d |  |  | start no earlier than 2002-05-23 | Drew | 16h | 16h |
| 136 | 1.6.3.5 | Lifting I beam in Lab | 5d | 2002-05-30 A | 2002-06-05 |  | 50% | 2.5d | 2002-05-30 | 2002-06-05 | 5d | 119d |  | start no earlier than 2002-05-30 | ME TECH | 40h | 20h |
| 137 | 1.6.3.6 | Cable trays nad outlets in lab ceiling | 5d | 2002-07-15 | 2002-07-19 |  |  |  | 2002-06-03 | 2002-06-07 | 5d | 87d |  | start no earlier than 2002-07-14 | ME TECH | 40h |  |
| 138 | 1.6.4 | **Sensor & Payload Mounts** | 5d | 2002-06-21 | 2002-06-27 |  |  |  | 2002-05-20 | 2002-05-28 | 7d | 95d | 10d |  |  | 72h |  |
| 139 | 1.6.4.1 | Antennaes | 5d | 2002-06-21 | 2002-06-27 |  |  |  | 2002-05-20 | 2002-05-24 | 5d | 95d |  | start no earlier than 2002-06-21 | Drew | 40h |  |
| 140 | 1.6.4.2 | ORE & various equip | 4d | 2002-06-24 | 2002-06-27 |  |  |  | 2002-05-23 | 2002-05-28 | 4d | 95d |  | start no earlier than 2002-06-24 | Drew | 32h |  |
| 141 | 1.6.5 | **Buoyancy** | 21d | 2002-06-13 | 2002-07-11 |  |  |  | 2002-05-22 | 2002-06-04 | 10d | 85d | 0d |  |  | 144h |  |
| 142 | 1.6.5.1 | Tailcone Foam Pack Specification | 5d | 2002-06-28 | 2002-07-04 |  |  |  | 2002-05-22 | 2002-05-28 | 5d | 85d | 0d | start no earlier than 2002-06-28 | Farley | 40h |  |
| 143 | 1.6.5.2 | Tailcone foam machining | 5d | 2002-07-05 | 2002-07-11 | 142 |  |  | 2002-05-29 | 2002-06-04 | 5d | 85d |  |  | Farley | 40h |  |
| 144 | 1.6.5.3 | Modular trim / ballast systems concept | 8d | 2002-06-13 | 2002-06-24 |  |  |  | 2002-05-22 | 2002-05-28 | 5d | 98d |  | start no earlier than 2002-06-13 | Rob | 64h |  |
| 145 | 1.6.6 | **Fairing Build** | 8d | 2002-07-12 | 2002-07-23 | 138, 141 |  |  | 2002-06-10 | 2002-06-26 | 13d | 85d |  |  |  | 192h |  |
| 146 | 1.6.6.1 | Noes section (2 plus 1 spare) | 8d | 2002-07-12 | 2002-07-23 |  |  |  | 2002-06-10 | 2002-06-19 | 8d | 85d |  | start no earlier than 2002-06-10 | ME TECH | 64h |  |
| 147 | 1.6.6.2 | Midboady (2 plus 1 spare) | 8d | 2002-07-12 | 2002-07-23 |  |  |  | 2002-06-13 | 2002-06-24 | 8d | 85d |  | start no earlier than 2002-06-13 | ME TECH | 64h |  |
| 148 | 1.6.6.3 | Tail section (2 plus 1 spare) | 8d | 2002-07-12 | 2002-07-23 |  |  |  | 2002-06-17 | 2002-06-26 | 8d | 85d |  | start no earlier than 2002-06-17 | ME TECH | 64h |  |

| ID | WBS | Task | Duration | Start | Finish | Predecessors | Complete | Remaining | Baseline start | Baseline finish | Baseline duration | Total slack | Free slack | Constraint | Resources | Work | Actual work |
| --- | --- | --- | --- | --- | --- | --- | --- | --- | --- | --- | --- | --- | --- | --- | --- | --- | --- |
| 150 | 1.7 | **Software** | 119d | 2002-06-06 A | 2002-11-19 |  | 4% | 114.15d | 2002-06-24 | 2002-11-19 | 107d | 0d |  |  | Hans | 3452h | 143.01h |
| 151 | 1.7.1 | Change supervisor so drivers run all the time | 3d | 2002-09-02 | 2002-09-04 |  |  |  | 2002-09-02 | 2002-09-04 | 3d | 50d | 0d | start no earlier than 2002-09-02 | Hans [50%] | 12h |  |
| 152 | 1.7.2 | Chang logging to convert files to MATLAB | 4d | 2002-09-05 | 2002-09-10 | 151 |  |  | 2002-09-05 | 2002-09-10 | 4d | 50d |  |  | Hans [50%] | 16h |  |
| 153 | 1.7.3 | **OS Upgrade** | 6d | 2002-09-12 | 2002-09-19 |  |  |  | 2002-09-12 | 2002-09-19 | 6d | 43d |  |  | Sib | 96h |  |
| 154 | 1.7.3.1 | QNX Upgrade to Neutrino | 3d | 2002-09-12 | 2002-09-16 |  |  |  | 2002-09-12 | 2002-09-16 | 3d | 43d | 0d | start no earlier than 2002-09-12 | Kent | 24h |  |
| 155 | 1.7.3.2 | Eval Linux for possible upgrade in future | 3d | 2002-09-17 | 2002-09-19 | 154 |  |  | 2002-09-17 | 2002-09-19 | 3d | 43d |  |  | Kent | 24h |  |
| 156 | 1.7.4 | **GUI** | 50d | 2002-06-06 | 2002-08-14 |  |  |  | 2002-07-02 | 2002-09-09 | 50d | 69d |  |  | Rich | 800h |  |
| 157 | 1.7.4.1 | gather requirements | 5d | 2002-06-06 | 2002-06-12 |  |  |  | 2002-07-02 | 2002-07-08 | 5d | 69d | 0d | start no earlier than 2002-06-06 | Rich | 40h |  |
| 158 | 1.7.4.2 | eval Bluefin GUI | 10d | 2002-06-13 | 2002-06-26 | 157 |  |  | 2002-07-09 | 2002-07-22 | 10d | 69d | 0d |  | Rich | 80h |  |
| 159 | 1.7.4.3 | develop GUI plan | 5d | 2002-06-27 | 2002-07-03 | 158 |  |  | 2002-07-23 | 2002-07-29 | 5d | 69d | 0d |  | Rich | 40h |  |
| 160 | 1.7.4.4 | Detail GUI development (TBD) | 30d | 2002-07-04 | 2002-08-14 | 159 |  |  | 2002-07-30 | 2002-09-09 | 30d | 69d |  |  | Rich | 240h |  |
| 161 | 1.7.5 | Configuration management on vehicle (config files) | 15d | 2002-07-09 | 2002-07-29 |  |  |  | 2002-08-16 | 2002-09-05 | 15d | 81d |  | start no earlier than 2002-07-09 | Rich | 120h |  |
| 162 | 1.7.6 | **Controls** | 45d | 2002-07-19 | 2002-09-19 |  |  |  | 2002-06-24 | 2002-08-23 | 45d | 43d |  |  | Rob | 720h |  |
| 163 | 1.7.6.1 | depth control improvement (long configs) | 15d | 2002-07-19 | 2002-08-08 |  |  |  | 2002-06-24 | 2002-07-12 | 15d | 43d | 0d | start no earlier than 2002-07-19 | Rob | 120h |  |
| 164 | 1.7.6.2 | sway / yaw control coupling (heave/ pitch too) | 10d | 2002-08-09 | 2002-08-22 | 163 |  |  | 2002-07-15 | 2002-07-26 | 10d | 43d | 0d |  | Rob | 80h |  |
| 165 | 1.7.6.3 | slow speed dynamics for control | 20d | 2002-08-23 | 2002-09-19 | 164 |  |  | 2002-07-29 | 2002-08-23 | 20d | 43d |  |  | Rob | 160h |  |
| 166 | 1.7.7 | **Navigation Software** | 42d | 2002-09-23 A | 2002-11-19 |  | 13% | 36.47d | 2002-09-23 | 2002-11-19 | 42d | 0d |  |  | Hans | 684h | 104.21h |
| 167 | 1.7.7.1 | Document current NAV sys | 4d | 2002-09-23 | 2002-09-26 |  |  |  | 2002-09-23 | 2002-09-26 | 4d | 0d |  | start no earlier than 2002-09-23 | Hans [50%] | 16h |  |
| 168 | 1.7.7.2 | Streamline current nav architecture | 8d | 2002-09-27 | 2002-10-08 | 167 |  |  | 2002-09-27 | 2002-10-08 | 8d | 0d |  |  | Hans [50%] | 32h |  |
| 169 | 1.7.7.3 | Single beacon homing | 15d | 2002-10-09 | 2002-10-29 | 168 |  |  | 2002-10-09 | 2002-10-29 | 15d | 0d |  |  | Hans [50%] | 60h |  |
| 170 | 1.7.7.4 | Single beacon LBL | 15d | 2002-10-30 | 2002-11-19 | 169 |  |  | 2002-10-30 | 2002-11-19 | 15d | 0d |  |  | Hans | 120h |  |
| 171 | 1.7.7.5 | DVL driver enhancements for PD5 | 15d | 2002-10-09 A | 2002-10-29 | 168 | 50% | 7.5d | 2002-10-09 | 2002-10-29 | 15d | 15d |  |  | Rob | 120h | 60h |
| 172 | 1.7.8 | **Intra-vehicle Comms** | 4d | 2002-10-01 | 2002-10-04 |  |  |  | 2002-10-01 | 2002-10-04 | 4d | 32d |  |  | Sib | 52h |  |
| 173 | 1.7.8.1 | set up socket code (for reconnects) | 3d | 2002-10-01 | 2002-10-03 |  |  |  | 2002-10-01 | 2002-10-03 | 3d | 32d | 0d | start no earlier than 2002-10-01 | Hans [50%] | 12h |  |
| 174 | 1.7.8.2 | briding over wireless | 1d | 2002-10-04 | 2002-10-04 | 173 |  |  | 2002-10-04 | 2002-10-04 | 1d | 32d |  |  | Sib | 8h |  |

| ID | WBS | Task | Duration | Start | Finish | Predecessors | Complete | Remaining | Baseline start | Baseline finish | Baseline duration | Total slack | Free slack | Constraint | Resources | Work | Actual work |
| --- | --- | --- | --- | --- | --- | --- | --- | --- | --- | --- | --- | --- | --- | --- | --- | --- | --- |
| 176 | 1.8 | **Vehicle Integration and Test** | 35d | 2002-07-18 | 2002-09-04 |  |  |  | 2002-06-10 | 2002-08-02 | 40d | 53d | 0d |  | Hans | 552h |  |
| 177 | 1.8.1 | Tailcone Assembly | 5d | 2002-07-18 | 2002-07-24 |  |  |  | 2002-06-10 | 2002-06-14 | 5d | 62d | 0d | start no earlier than 2002-07-18 | Hans [50%] | 20h |  |
| 178 | 1.8.2 | Tailcone Test | 4d | 2002-07-25 | 2002-07-30 | 177 |  |  | 2002-06-17 | 2002-06-20 | 4d | 62d | 9d |  | Sib [50%] | 16h |  |
| 179 | 1.8.3 | Battery Midbody Integration | 5d | 2002-07-31 | 2002-08-06 |  |  |  | 2002-06-17 | 2002-06-21 | 5d | 53d | 0d | start no earlier than 2002-07-31 | Hans [50%] | 20h |  |
| 180 | 1.8.4 | Battery Midbody Test | 4d | 2002-08-07 | 2002-08-12 | 179 |  |  | 2002-06-24 | 2002-06-27 | 4d | 53d | 0d |  | Sib [50%] | 16h |  |
| 181 | 1.8.5 | ALTEX Nose Payload Assembly/Upgrade | 5d | 2002-07-19 | 2002-07-25 |  |  |  | 2002-06-17 | 2002-06-21 | 5d | 56d | 0d | start no earlier than 2002-07-19 | Drew | 40h |  |
| 182 | 1.8.6 | Science Payload Assembly | 6d | 2002-07-26 | 2002-08-02 | 181 |  |  | 2002-06-24 | 2002-07-01 | 6d | 56d | 0d | start no earlier than 2002-06-07 |  |  |  |
| 183 | 1.8.7 | Payload Test | 3d | 2002-08-05 | 2002-08-07 | 182 |  |  | 2002-07-02 | 2002-07-04 | 3d | 56d | 3d |  | Drew | 24h |  |
| 184 | 1.8.8 | Integrated Vehcile Deck Assembly | 2d | 2002-08-13 | 2002-08-14 | 178, 180, 183 |  |  | 2002-07-05 | 2002-07-08 | 2d | 53d | 0d |  | Drew | 16h |  |
| 185 | 1.8.9 | Vehicle Ballasting | 1d | 2002-08-15 | 2002-08-15 | 184 |  |  | 2002-07-09 | 2002-07-09 | 1d | 53d | 0d |  | Drew | 8h |  |
| 186 | 1.8.10 | Integrated Vehicle Deck Test | 3d | 2002-08-16 | 2002-08-20 | 185 |  |  | 2002-07-10 | 2002-07-12 | 3d | 53d | 0d |  | Drew | 24h |  |
| 187 | 1.8.11 | Integrated Vehicle Tank Test | 5d | 2002-08-21 | 2002-08-27 | 186 |  |  | 2002-07-15 | 2002-07-19 | 5d | 53d | 0d |  | Drew | 40h |  |
| 188 | 1.8.12 | Integrated Vehicle Sea Trials | 6d | 2002-08-28 | 2002-09-04 | 187 |  |  | 2002-07-22 | 2002-08-02 | 10d | 53d |  |  | Drew | 48h |  |
| 190 | 1.9 | **CTD Science Payload Core** | 51d? | 2002-06-27 A | 2002-09-05 |  | 8% | 46.89d? | 2002-06-20 | 2002-08-05 | 33d? | 53d |  |  | Drew | 648h | 52.9h |
| 191 | 1.9.1 | Repair/Replace nose fairing | 3d | 2002-07-22 | 2002-07-24 |  |  |  | 2002-06-20 | 2002-06-24 | 3d | 78d | 0d | start no earlier than 2002-07-20 | ME TECH | 24h |  |
| 192 | 1.9.2 | recable Dcon to comms and pwr bus | 8d | 2002-07-29 | 2002-08-07 |  |  |  | 2002-06-21 | 2002-07-02 | 8d | 70d | 0d | start no earlier than 2002-07-27 | EE TECH | 64h |  |
| 193 | 1.9.3 | Design HS2 Mount | 2d | 2002-07-25 | 2002-07-26 | 191 |  |  | 2002-06-25 | 2002-06-26 | 2d | 78d | 0d |  | ME TECH | 16h |  |
| 194 | 1.9.4 | Build HS2 Mount | 2d | 2002-07-29 | 2002-07-30 | 193 |  |  | 2002-06-27 | 2002-06-28 | 2d | 78d | 0d |  | ME TECH | 16h |  |
| 195 | 1.9.5 | Assembly HS2 Mount | 2d | 2002-07-31 | 2002-08-01 | 194 |  |  | 2002-07-01 | 2002-07-02 | 2d | 78d |  |  | ME TECH | 16h |  |
| 196 | 1.9.6 | Write test driver HS2 | 5d | 2002-06-27 A | 2002-07-03 |  | 50% | 2.5d | 2002-06-27 | 2002-07-03 | 5d | 99d |  | start no earlier than 2002-06-27 | Rich | 40h | 20h |
| 197 | 1.9.7 | Eval Foam buoyancy cooridnate 1500 M version | 5d | 2002-06-28 | 2002-07-04 |  |  |  | 2002-06-28 | 2002-07-04 | 5d | 98d |  | start no earlier than 2002-06-28 | Farley | 40h |  |
| 198 | 1.9.8 | repair flow sensor #2 | 3d | 2002-08-08 | 2002-08-12 | 192 |  |  | 2002-07-03 | 2002-07-05 | 3d | 70d | 17d |  | EE TECH | 24h |  |
| 199 | 1.9.9 | test integrated CTD Payload | 1d? | 2002-09-05 | 2002-09-05 | 198, 176 |  |  | 2002-08-05 | 2002-08-05 | 1d? | 53d |  |  |  |  |  |
| 201 | 1.10 | **CTD Extension for Ryan/Haddock** | 21d | 2002-06-27 | 2002-07-25 |  |  |  | 2002-06-03 | 2002-07-01 | 21d | 83d |  |  | Drew | 488h |  |
| 202 | 1.10.1 | Design LISST pump assy | 4d | 2002-06-27 | 2002-07-02 |  |  |  | 2002-06-03 | 2002-06-06 | 4d | 83d | 0d | start no earlier than 2002-06-27 | Drew [50%] | 16h |  |
| 203 | 1.10.2 | Fab LISST pump assy | 5d | 2002-07-03 | 2002-07-09 | 202 |  |  | 2002-06-07 | 2002-06-13 | 5d | 86d | 0d |  | Shop | 40h |  |
| 204 | 1.10.3 | Assy LISST pump into vehicle | 2d | 2002-07-10 | 2002-07-11 | 203 |  |  | 2002-06-14 | 2002-06-17 | 2d | 86d | 3d |  | ME TECH | 16h |  |
| 205 | 1.10.4 | Design LISST mount | 5d | 2002-07-03 | 2002-07-09 | 202 |  |  | 2002-06-07 | 2002-06-13 | 5d | 83d | 0d |  | Farley | 40h |  |
| 206 | 1.10.5 | Fab LISST Mount | 5d | 2002-07-10 | 2002-07-16 | 205 |  |  | 2002-06-14 | 2002-06-20 | 5d | 83d | 0d |  | Shop | 40h |  |
| 207 | 1.10.6 | Assy LISST mount | 2d | 2002-07-17 | 2002-07-18 | 204, 206 |  |  | 2002-06-21 | 2002-06-24 | 2d | 83d | 0d |  | ME TECH | 16h |  |
| 208 | 1.10.7 | Cable LISST to Dcon | 1d | 2002-07-19 | 2002-07-19 | 207 |  |  | 2002-06-25 | 2002-06-25 | 1d | 87d |  |  | EE TECH | 8h |  |
| 209 | 1.10.8 | Write Test Driver for LISST | 5d | 2002-07-19 | 2002-07-25 | 207 |  |  | 2002-06-25 | 2002-07-01 | 5d | 83d |  |  | Rich | 40h |  |
| 210 | 1.10.9 | Design Bathypho mount | 4d | 2002-07-03 | 2002-07-08 |  |  |  | 2002-06-05 | 2002-06-10 | 4d | 85d | 0d | start no earlier than 2002-07-03 | Drew [50%] | 16h |  |
| 211 | 1.10.10 | Fab Bathypho mount | 5d | 2002-07-09 | 2002-07-15 | 210 |  |  | 2002-06-11 | 2002-06-17 | 5d | 85d | 0d |  | ME TECH | 40h |  |
| 212 | 1.10.11 | Assy Bathypho mount | 2d | 2002-07-16 | 2002-07-17 | 211 |  |  | 2002-06-18 | 2002-06-19 | 2d | 85d | 0d |  | ME TECH | 16h |  |
| 213 | 1.10.12 | Cable Bathypho to Dcon | 1d | 2002-07-18 | 2002-07-18 | 212 |  |  | 2002-06-20 | 2002-06-20 | 1d | 85d | 0d |  | EE TECH | 8h |  |
| 214 | 1.10.13 | Retest driver for Bathypho (already written) | 3d | 2002-07-19 | 2002-07-23 | 213 |  |  | 2002-06-21 | 2002-06-25 | 3d | 85d |  |  | Rich | 24h |  |
| 216 | 1.11 | Ryan / Haddock Cruise Prep | 14d | 2002-08-05 | 2002-08-22 |  |  |  | 2002-07-29 | 2002-08-15 | 14d | 63d |  | start no earlier than 2002-08-05 | Hans | 112h |  |
